# Sensores_FIni_It2

Schedule from MS Project, 2014-08-15 to 2014-11-24, 6 hours a day, A marks actual dates.

## Calendars

- Copia de Estándar: Mon-Sun 09:00-20:00.

## Resources

| Resource | Group |
| --- | --- |
| Ana Clara E | A;DU;AsistVerif |
| Santiago B | A;I; |
| Diego S | Arquitecto |
| Oscar M | SQA;AsistVerif |
| Fernando P | Verif;AsistSQA |
| Juan C | A;I;DisI |
| Fabricio G | A;I;DisI |
| Mathias B | EspTecnico;I |
| Mathias F | EspTecnico;I |
| Rolando L | EspTecnico;I |
| Emiliano T | SCM;EspTecnico;I |
| Santiago F | EspTecnico;I |
| Ignacio A | Admin |
| TODOS |  |
| Analistas |  |
| Implementadores |  |
| DS |  |
| ET |  |
| SF |  |
| MB |  |
| MF |  |
| SB |  |
| JC |  |
| FG |  |
| RL |  |
| FP |  |
| IA |  |
| OM |  |
| AE |  |
| Resp Integración |  |
| Verificadores |  |

## Schedule

| ID | WBS | Task | Type | Duration | Start | Finish | Predecessors | Complete | Actual finish | Resources | Work | Actual work |
| --- | --- | --- | --- | --- | --- | --- | --- | --- | --- | --- | --- | --- |
| 1 | 1 | **Fase Inicial** |  | 58.5d | 2014-08-15 A | 2014-09-15 |  | 100% | 2014-09-08 |  | 1424h | 1424h |
| 2 | 1.1 | **Iteración 1** |  | 32.83d | 2014-08-15 A | 2014-09-01 A |  | 100% |  |  | 687h | 687h |
| 3 | 1.1.1 | **Semana 1** |  | 16.5d | 2014-08-15 A | 2014-08-24 A |  | 100% |  |  | 217h | 217h |
| 4 | 1.1.1.1 | Reunión de Equipo (0) | milestone, manual | 0h | 2014-08-15 A | 2014-08-15 A |  | 100% |  | Ana Clara E; Diego S; Emiliano T; Fabricio G; Fernando P; Ignacio A; Juan C; Mathias B; Mathias F; Oscar M; Rolando L; Santiago B; Santiago F | 26h | 26h |
| 5 | 1.1.1.2 | Elaborar acta de reunión de equipo (0) | milestone, manual | 0h | 2014-08-15 A | 2014-08-15 A | 4 | 100% |  | Ignacio A | 1h | 1h |
| 6 | 1.1.1.3 | Elaborar Plan de iteración 1 (0) | milestone, manual | 0h | 2014-08-16 A | 2014-08-16 A |  | 100% |  | Ignacio A | 4h | 4h |
| 7 | 1.1.1.4 | Entrega 0 | milestone, manual | 0d | 2014-08-17 A | 2014-08-17 A | 4, 5, 6 | 100% |  |  |  |  |
| 8 | 1.1.1.5 | Probar tecnologías PostGIS, GeoServer | manual | 5.83d | 2014-08-15 A | 2014-08-18 A |  | 100% |  | Mathias B; Mathias F; Rolando L; Santiago F | 44h | 44h |
| 9 | 1.1.1.6 | Reunión de Requerimientos (1) | milestone, manual | 0h | 2014-08-18 A | 2014-08-18 A |  | 100% |  | Ana Clara E; Diego S; Emiliano T; Fabricio G; Fernando P; Ignacio A; Juan C; Mathias B; Mathias F; Oscar M; Rolando L; Santiago B; Santiago F | 13h | 13h |
| 10 | 1.1.1.7 | Elaborar acta de reunión de requerimientos (1) | milestone, manual | 0h | 2014-08-18 A | 2014-08-18 A | 9 | 100% |  | Ana Clara E; Fabricio G; Juan C; Santiago B | 8h | 8h |
| 11 | 1.1.1.8 | Especificar requerimientos (1) | milestone, manual | 0h | 2014-08-19 A | 2014-08-19 A | 13 | 100% |  | Ana Clara E; Fabricio G; Juan C; Santiago B | 24h | 24h |
| 12 | 1.1.1.9 | Reunión de Requerimientos (1) | milestone, manual | 0h | 2014-08-19 A | 2014-08-19 A | 9 | 100% |  | Ana Clara E; Fabricio G; Juan C; Santiago B; Diego S; Fernando P; Ignacio A; Oscar M | 8h | 8h |
| 13 | 1.1.1.10 | Elaborar acta de reunión de requerimientos (1) | milestone, manual | 0h | 2014-08-19 A | 2014-08-19 A | 10, 12 | 100% |  | Ana Clara E; Fabricio G; Juan C; Santiago B | 4h | 4h |
| 14 | 1.1.1.11 | Elaborar documento informativo(1) | milestone, manual | 0h | 2014-08-19 A | 2014-08-19 A | 23 | 100% |  | Ignacio A | 1h | 1h |
| 15 | 1.1.1.12 | Definir Glosario (1) | milestone, manual | 0h | 2014-08-20 A | 2014-08-20 A | 11 | 100% |  | Ana Clara E; Fabricio G; Juan C; Santiago B | 8h | 8h |
| 16 | 1.1.1.13 | Elaborar informe de situación de proyecto (1) | milestone, manual | 0h | 2014-08-18 A | 2014-08-19 A | 20 | 100% |  | Ignacio A | 6h | 6h |
| 17 | 1.1.1.14 | Elaborar modelo de dominio (1) | milestone, manual | 0h | 2014-08-20 A | 2014-08-20 A | 11 | 100% |  | Ana Clara E; Fabricio G; Juan C; Santiago B; Diego S | 20h | 20h |
| 18 | 1.1.1.15 | Modelo de Dominio (1) | milestone, manual | 0d | 2014-08-21 A | 2014-08-21 A | 17 | 100% |  |  |  |  |
| 19 | 1.1.1.16 | Pautas para la interfaz de usuario (1) | milestone, manual | 0d | 2014-08-18 A | 2014-08-18 A |  | 100% |  | Juan C; Fabricio G | 8h | 8h |
| 20 | 1.1.1.17 | Registro de actividades (1) | milestone, manual | 0h | 2014-08-18 A | 2014-08-18 A |  | 100% |  | Ana Clara E; Diego S; Emiliano T; Fabricio G; Fernando P; Ignacio A; Juan C; Mathias B; Mathias F; Oscar M; Rolando L; Santiago B; Santiago F | 13h | 13h |
| 21 | 1.1.1.18 | Especificar Casos de uso (2) | manual | 4h | 2014-08-21 A | 2014-08-21 A | 10 | 100% |  | Ana Clara E; Fabricio G; Fernando P; Juan C; Oscar M; Santiago B | 24h | 24h |
| 22 | 1.1.1.19 | Modelo de casos de uso (2) | milestone, manual | 0d | 2014-08-21 A | 2014-08-21 A | 21 | 100% |  | Ana Clara E; Fabricio G; Fernando P; Juan C; Oscar M; Santiago B |  |  |
| 23 | 1.1.1.20 | Descripción del Proyecto (1) | milestone, manual | 0h | 2014-08-18 A | 2014-08-18 A |  | 100% |  | Ignacio A | 4h | 4h |
| 24 | 1.1.1.21 | Revisar entregas semana (1) | milestone, manual | 0h | 2014-08-22 A | 2014-08-22 A | 13, 11, 14, 15, 16, 18, 19, 20, 22, 23 | 100% |  | Oscar M | 1h | 1h |
| 25 | 1.1.1.22 | Entrega 1 | milestone, manual | 0d | 2014-08-24 A | 2014-08-24 A | 24 | 100% |  | Ana Clara E; Diego S; Emiliano T; Fabricio G; Fernando P; Ignacio A; Juan C; Mathias B; Mathias F; Oscar M; Rolando L; Santiago B; Santiago F |  |  |

| ID | WBS | Task | Type | Duration | Start | Finish | Predecessors | Complete | Resources | Work | Actual work |
| --- | --- | --- | --- | --- | --- | --- | --- | --- | --- | --- | --- |
| 26 | 1.1.2 | **Semana 2** |  | 14.5d | 2014-08-25 A | 2014-09-01 A |  | 100% |  | 470h | 470h |
| 27 | 1.1.2.1 | Reunión de Requerimientos (2) | manual | 1h | 2014-08-27 A | 2014-08-27 A | 9 | 100% | Ana Clara E; Fabricio G; Juan C; Santiago B; Diego S; Fernando P; Ignacio A; Oscar M | 8h | 8h |
| 28 | 1.1.2.2 | Elaborar acta de reunión de requerimientos (2) | manual | 1h | 2014-08-27 A | 2014-08-27 A | 27, 10 | 100% | Ana Clara E; Fabricio G; Juan C; Santiago B | 4h | 4h |
| 29 | 1.1.2.3 | Especificar requerimientos (2) | manual | 4h | 2014-08-27 A | 2014-08-27 A | 28 | 100% |  |  |  |
| 30 | 1.1.2.4 | Definir Glosario (2) | manual | 2h | 2014-08-27 A | 2014-08-27 A | 15, 29 | 100% | Ana Clara E; Fabricio G; Juan C; Santiago B | 8h | 8h |
| 31 | 1.1.2.5 | Especificar Casos de uso (2) | manual | 10h | 2014-08-27 A | 2014-08-27 A | 29 | 100% | Ana Clara E; Fabricio G; Fernando P; Juan C; Oscar M; Santiago B | 54h | 54h |
| 32 | 1.1.2.6 | Modelo de casos de uso (2) | milestone, manual | 0d | 2014-08-27 A | 2014-08-27 A | 31 | 100% |  |  |  |
| 33 | 1.1.2.7 | Priorizar casos de uso (2) | manual | 2h | 2014-08-27 A | 2014-08-27 A | 32, 22 | 100% | Diego S; Fabricio G; Fernando P; Juan C; Oscar M | 10h | 10h |
| 34 | 1.1.2.8 | Describir Arquitectura (Vista del modelo de casos de uso)(2) | manual | 4h | 2014-08-28 A | 2014-08-28 A | 33 | 100% | Ana Clara E; Diego S; Fabricio G; Juan C; Santiago B | 20h | 20h |
| 35 | 1.1.2.9 | Descripción de la Arquitectura (Vista del modelo de casos de uso) (2) | milestone, manual | 0d | 2014-08-28 A | 2014-08-28 A | 34 | 100% |  |  |  |
| 36 | 1.1.2.10 | Validación con el cliente (2) | manual | 1h | 2014-08-25 A | 2014-08-25 A |  | 100% | Diego S | 1h | 1h |
| 37 | 1.1.2.11 | Documento de validación con el cliente (2) | milestone, manual | 0d | 2014-08-25 A | 2014-08-25 A | 36 | 100% | Diego S |  |  |
| 38 | 1.1.2.12 | Modificaciones correspondientes al modelo de dominio (2) | manual | 6h | 2014-08-26 A | 2014-08-26 A | 18, 29 | 100% | Ana Clara E; Fabricio G; Juan C; Santiago B; Diego S | 20h | 20h |
| 39 | 1.1.2.13 | Modelo de Dominio (2) | milestone, manual | 0d | 2014-08-26 A | 2014-08-26 A | 38 | 100% | Ana Clara E; Fabricio G; Juan C; Santiago B; Diego S |  |  |
| 40 | 1.1.2.14 | Definir Pautas para la Interfaz de usuario (2) | manual | 8h | 2014-08-27 A | 2014-08-27 A | 28, 32, 22 | 100% | Fabricio G; Juan C | 12h | 12h |
| 41 | 1.1.2.15 | Diseñar casos de uso (2) | manual | 10h | 2014-08-28 A | 2014-08-28 A | 30, 29, 32, 40, 22 | 100% | Ana Clara E; Diego S; Santiago B | 24h | 24h |
| 42 | 1.1.2.16 | Modelo de diseño (2) | milestone, manual | 0d | 2014-08-29 A | 2014-08-29 A | 41 | 100% | Diego S |  |  |
| 43 | 1.1.2.17 | Describir Arquitectura (Completa) (2) | manual | 8h | 2014-08-28 A | 2014-08-28 A | 29, 30, 32, 22 | 100% | Diego S; Ana Clara E; Fabricio G; Juan C; Santiago B | 30h | 30h |
| 44 | 1.1.2.18 | Descripción de la arquitectura (Completa) (2) | milestone, manual | 0d | 2014-08-28 A | 2014-08-28 A | 43 | 100% | Diego S |  |  |
| 45 | 1.1.2.19 | Documentar Requerimientos para el prototipo (2) | manual | 6h | 2014-08-27 A | 2014-08-27 A | 32, 29, 22 | 100% | Diego S; Ana Clara E; Fabricio G; Juan C; Santiago B | 20h | 20h |
| 46 | 1.1.2.20 | Documento de Requerimientos para el prototipo (2) | milestone, manual | 0d | 2014-08-28 A | 2014-08-28 A | 45 | 100% | Diego S |  |  |
| 47 | 1.1.2.21 | Diseñar prototipo (2) | manual | 4h | 2014-08-29 A | 2014-08-29 A | 46, 42 | 100% | Diego S; Mathias B; Mathias F; Rolando L; Santiago F | 40h | 40h |
| 48 | 1.1.2.22 | Documento de diseño del prototipo (2) | milestone, manual | 0d | 2014-08-31 A | 2014-08-31 A | 47 | 100% | Mathias B; Mathias F; Rolando L; Santiago F |  |  |
| 49 | 1.1.2.23 | Definir estándares de documentación técnica (2) | manual | 4h | 2014-08-25 A | 2014-08-25 A |  | 100% | Mathias B; Mathias F; Rolando L; Santiago F | 16h | 16h |
| 50 | 1.1.2.24 | Estándar de documentación técnica (2) | milestone, manual | 0d | 2014-08-25 A | 2014-08-25 A | 49 | 100% | Mathias B; Mathias F; Rolando L; Santiago F |  |  |
| 51 | 1.1.2.25 | Estándar de implementación (2) | milestone, manual | 0d | 2014-08-25 A | 2014-08-25 A | 49 | 100% | Mathias B; Mathias F; Rolando L; Santiago F |  |  |
| 52 | 1.1.2.26 | Planificar la verificación (2) | manual | 6h | 2014-08-27 A | 2014-08-27 A | 29, 32, 22 | 100% | Fernando P | 4h | 4h |
| 53 | 1.1.2.27 | Plan de verificación y validación (2) | milestone, manual | 0d | 2014-08-27 A | 2014-08-27 A | 52 | 100% | Fernando P |  |  |
| 54 | 1.1.2.28 | Definir alcance del sistema (2) | manual | 4h | 2014-08-28 A | 2014-08-28 A | 29, 30, 32, 40, 22 | 100% | Ana Clara E; Diego S; Fabricio G; Ignacio A; Juan C; Santiago B | 24h | 24h |
| 55 | 1.1.2.29 | Alcance del sistema (2) | milestone, manual | 0d | 2014-08-28 A | 2014-08-28 A | 54 | 100% |  |  |  |
| 56 | 1.1.2.30 | Elaborar plan de desarrollo (2) | manual | 5h | 2014-08-28 A | 2014-08-29 A | 54, 6 | 100% | Diego S | 4h | 4h |
| 57 | 1.1.2.31 | Plan de desarrollo (2) | milestone, manual | 0d | 2014-08-29 A | 2014-08-29 A | 56 | 100% | Diego S |  |  |
| 58 | 1.1.2.32 | Implementar el prototipo (2) | manual | 4h | 2014-08-29 A | 2014-08-29 A | 42, 57, 44, 6 | 100% | Diego S; Fabricio G; Juan C; Mathias B; Mathias F; Rolando L; Santiago B; Santiago F | 64h | 64h |
| 59 | 1.1.2.33 | Reunión de responsables por área (2) | manual | 1h | 2014-08-29 A | 2014-08-29 A |  | 100% | Ana Clara E; Diego S; Emiliano T; Fabricio G; Fernando P; Ignacio A; Juan C; Mathias B; Mathias F; Oscar M; Rolando L; Santiago B; Santiago F | 13h | 13h |
| 60 | 1.1.2.34 | Elaborar plan de iteración 2 (2) | manual | 8h | 2014-08-29 A | 2014-08-29 A | 59 | 100% | Ignacio A | 6h | 6h |
| 61 | 1.1.2.35 | Elaborar informe de situación de proyecto (2) | manual | 1h | 2014-09-01 A | 2014-09-01 A | 57, 60 | 100% | Diego S; Ignacio A | 2h | 2h |
| 62 | 1.1.2.36 | Estimaciones y mediciones (2) | manual | 1h | 2014-09-01 A | 2014-09-01 A | 54, 61, 57 | 100% | Ana Clara E; Diego S; Fabricio G; Ignacio A; Juan C; Santiago B | 6h | 6h |
| 63 | 1.1.2.37 | Elaborar documento de riesgos (2) | manual | 1h | 2014-09-01 A | 2014-09-01 A | 62, 61 | 100% | Emiliano T; Fabricio G; Fernando P; Ignacio A; Juan C; Mathias B; Mathias F; Oscar M; Rolando L; Santiago B; Santiago F; Ana Clara E; Diego S | 13h | 13h |
| 64 | 1.1.2.38 | Documento de riesgos (2) | milestone, manual | 0d | 2014-09-01 A | 2014-09-01 A | 63 | 100% | Ignacio A |  |  |
| 65 | 1.1.2.39 | Plan de Calidad (2) | manual | 1h | 2014-08-27 A | 2014-08-27 A | 28, 29, 32, 22 | 100% | Ana Clara E; Oscar M; Santiago B | 3h | 3h |
| 66 | 1.1.2.40 | Planificar configuración SCM (2) | manual | 2h | 2014-08-25 A | 2014-08-25 A |  | 100% | Emiliano T | 2h | 2h |
| 67 | 1.1.2.41 | Definir línea base (2) | manual | 2h | 2014-08-25 A | 2014-08-25 A |  | 100% | Emiliano T; Mathias B; Mathias F; Oscar M; Rolando L; Santiago F | 12h | 12h |
| 68 | 1.1.2.42 | Plan de configuración (2) | milestone | 0d | 2014-08-25 A | 2014-08-25 A | 66, 67 | 100% |  |  |  |
| 69 | 1.1.2.43 | Planificar el proyecto (2) | manual | 4h | 2014-09-01 A | 2014-09-01 A | 29, 55, 64, 62, 61, 32, 57, 53, 65, 68, 22 | 100% | Ignacio A; Emiliano T; Fernando P; Oscar M | 8h | 8h |
| 70 | 1.1.2.44 | Plan de proyecto (2) | milestone, manual | 0d | 2014-09-01 A | 2014-09-01 A | 69 | 100% | Ignacio A |  |  |
| 71 | 1.1.2.45 | Reunión de Equipo (2) | manual | 2h | 2014-08-29 A | 2014-08-29 A |  | 100% | Ana Clara E; Diego S; Emiliano T; Fabricio G; Fernando P; Ignacio A; Juan C; Mathias B; Mathias F; Oscar M; Rolando L; Santiago B; Santiago F | 26h | 26h |
| 72 | 1.1.2.46 | Elaborar acta de reunión de equipo (2) | milestone, manual | 0d | 2014-08-29 A | 2014-08-29 A | 71 | 100% | Ignacio A; Juan C |  |  |
| 73 | 1.1.2.47 | Definir ambiente controlado (2) | manual | 1h | 2014-08-27 A | 2014-08-27 A | 68 | 100% | Emiliano T; Mathias B; Mathias F; Rolando L; Santiago F | 5h | 5h |
| 74 | 1.1.2.48 | Definir documento de visión (2) | manual | 2h | 2014-08-27 A | 2014-08-27 A | 28, 29, 32, 23, 22, 76 | 100% | Ana Clara E; Fabricio G; Juan C; Santiago B | 8h | 8h |
| 75 | 1.1.2.49 | Lecciones Aprendidas (2) | manual | 1h | 2014-09-01 A | 2014-09-01 A | 61, 72 | 100% | Ignacio A | 1h | 1h |
| 76 | 1.1.2.50 | Descripción del Proyecto (2) | manual | 2h | 2014-08-26 A | 2014-08-26 A | 23, 29 | 100% | Ignacio A | 2h | 2h |
| 77 | 1.1.2.51 | Revisar entregas semana (2) | milestone, manual | 0h | 2014-09-01 A | 2014-09-01 A | 28, 29, 30, 35, 37, 39, 40, 44, 48, 46, 50, 51, 53, 58, 72, 64, 62, 61, 73, 65, 68, 57, 70, 60, 75, 74, 76 | 100% | Oscar M |  |  |
| 78 | 1.1.2.52 | Entrega Semana 2 | milestone, manual | 0d | 2014-09-01 A | 2014-09-01 A | 77 | 100% |  |  |  |

Notes:
- 33: http://www.fing.edu.uy/inco/cursos/ingsoft/pis/memoria/dvd02/experiencia2011/MUM/pluginMetodos/tasks/r4.priorizarCasosUso_9A040FCB.html
- 34: http://www.fing.edu.uy/inco/cursos/ingsoft/pis/memoria/dvd02/experiencia2011/MUM/pluginMetodos/deliveryprocesses/d2.describirArquitectura_4A39C5C0.html?proc=_lVXS4VGKEd6FIfGmpQJeqw&path=_lVXS4VGKEd6FIfGmpQJeqw,_0A4sIVGKEd6FIfGmpQJeqw,_AZLegVGLEd6FIfGmpQJe
- 36: http://www.fing.edu.uy/inco/cursos/ingsoft/pis/memoria/dvd02/experiencia2011/MUM/pluginMetodos/tasks/r5.validacionCliente_A64814D4.html
- 40: http://www.fing.edu.uy/inco/cursos/ingsoft/pis/memoria/dvd02/experiencia2011/MUM/pluginMetodos/tasks/r6.definirPautasInterfazUsuario_6623E117.html
- 41: http://www.fing.edu.uy/inco/cursos/ingsoft/pis/memoria/dvd02/experiencia2011/MUM/pluginMetodos/tasks/d1.disenarCasosUso_AB966D55.html
- 42: http://www.fing.edu.uy/inco/cursos/ingsoft/pis/memoria/dvd02/experiencia2011/MUM/pluginMetodos/workproducts/modeloDiseno_E50AFDE8.html
- 43: http://www.fing.edu.uy/inco/cursos/ingsoft/pis/memoria/dvd02/experiencia2011/MUM/pluginMetodos/tasks/d2.describirArquitectura_86A64863.html
- 45: http://www.fing.edu.uy/inco/cursos/ingsoft/pis/memoria/dvd02/experiencia2011/MUM/pluginMetodos/tasks/r10.documentarRequerimientos_58BF0A39.html
- 47: http://www.fing.edu.uy/inco/cursos/ingsoft/pis/memoria/dvd02/experiencia2011/MUM/pluginMetodos/tasks/d5.disenarPrototipo_9FF60F60.html
- 48: http://www.fing.edu.uy/inco/cursos/ingsoft/pis/memoria/dvd02/experiencia2011/MUM/pluginMetodos/workproducts/documentoDisenoPrototipo_E44B79F6.html
- 49: http://www.fing.edu.uy/inco/cursos/ingsoft/pis/memoria/dvd02/experiencia2011/MUM/pluginMetodos/tasks/i1.definirEstandaresDocumentacionTecnica_F5126C9D.html
- 50: http://www.fing.edu.uy/inco/cursos/ingsoft/pis/memoria/dvd02/experiencia2011/MUM/pluginMetodos/workproducts/estandarDocumentacionTecnica_F6E9D5F1.html
- 51: http://www.fing.edu.uy/inco/cursos/ingsoft/pis/memoria/dvd02/experiencia2011/MUM/pluginMetodos/workproducts/estandarImplementacion_2AF3D3A6.html?nodeId=8fc09fe6
- 52: http://www.fing.edu.uy/inco/cursos/ingsoft/pis/memoria/dvd02/experiencia2011/MUM/pluginMetodos/tasks/v1.planificarVerificacion_3403661D.html
- 54: http://www.fing.edu.uy/inco/cursos/ingsoft/pis/memoria/dvd02/experiencia2011/MUM/pluginMetodos/tasks/r7.definirAlcanceSistema_5C89EA15.html
- 58: http://www.fing.edu.uy/inco/cursos/ingsoft/pis/memoria/dvd02/experiencia2011/MUM/pluginMetodos/tasks/i2.implementarPrototipo_48D411B0.html
- 62: http://www.fing.edu.uy/inco/cursos/ingsoft/pis/memoria/dvd02/experiencia2011/MUM/pluginMetodos/tasks/g3.estimacionesMediciones_C6EFBC54.html
- 63: http://www.fing.edu.uy/inco/cursos/ingsoft/pis/memoria/dvd02/experiencia2011/MUM/pluginMetodos/tasks/g4.gestionRiesgos_68264CB.html
- 66: http://www.fing.edu.uy/inco/cursos/ingsoft/pis/memoria/dvd02/experiencia2011/MUM/pluginMetodos/tasks/c1.planificarConfiguracionSCM_A520CDE0.html
- 67: http://www.fing.edu.uy/inco/cursos/ingsoft/pis/memoria/dvd02/experiencia2011/MUM/pluginMetodos/tasks/c2.definirLineaBaseProyecto_426D6B5B.html
- 69: http://www.fing.edu.uy/inco/cursos/ingsoft/pis/memoria/dvd02/experiencia2011/MUM/pluginMetodos/tasks/g1.planificarProyecto_73EFE8AB.html
- 70: http://www.fing.edu.uy/inco/cursos/ingsoft/pis/memoria/dvd02/experiencia2011/MUM/pluginMetodos/workproducts/planProyecto_D7DA434B.html
- 73: http://www.fing.edu.uy/inco/cursos/ingsoft/pis/memoria/dvd02/experiencia2011/MUM/pluginMetodos/tasks/c4.DefinirAmbienteControlado_5592AFA.html
- 74: http://www.fing.edu.uy/inco/cursos/ingsoft/pis/memoria/dvd02/experiencia2011/MUM/pluginMetodos/workproducts/documentoVision_5EDFAF07.html?nodeId=4520df79
- 75: http://www.fing.edu.uy/inco/cursos/ingsoft/pis/memoria/dvd02/experiencia2011/MUM/pluginMetodos/tasks/g20.gestionLeccionesAprendidas_261DF3E0.html
- 77: http://www.fing.edu.uy/inco/cursos/ingsoft/pis/memoria/dvd02/experiencia2011/MUM/pluginMetodos/workproducts/entregaSemanalSQA_E5B566DC.html?nodeId=3986a8f6

| ID | WBS | Task | Type | Duration | Start | Finish | Predecessors | Complete | Actual finish | Resources | Work | Actual work |
| --- | --- | --- | --- | --- | --- | --- | --- | --- | --- | --- | --- | --- |
| 79 | 1.2 | **Iteración 2** |  | 25.5d | 2014-09-02 A | 2014-09-15 |  | 100% | 2014-09-08 |  | 737h | 737h |
| 80 | 1.2.1 | **Diseño** |  | 1.83d? | 2014-09-02 A | 2014-09-02 |  | 100% | 2014-09-04 |  | 88h | 88h |
| 81 | 1.2.1.1 | **D1 - Diseñar casos de uso** |  | 1.83d | 2014-09-02 A | 2014-09-03 A | 141, 142, 146, 148 | 100% |  | Diego S; Ana Clara E; Fabricio G; Juan C; Santiago B | 40h | 40h |
| 82 | 1.2.1.1.1 | Log in / Log out | manual | 1.83d | 2014-09-02 A | 2014-09-03 A |  | 100% |  |  |  |  |
| 83 | 1.2.1.1.2 | ABM Usuario | manual | 1.83d | 2014-09-02 A | 2014-09-03 A |  | 100% |  |  |  |  |
| 84 | 1.2.1.1.3 | AMB Red | manual | 1.83d | 2014-09-02 A | 2014-09-03 A |  | 100% |  |  |  |  |
| 85 | 1.2.1.1.4 | Asignar/Desasignar agrónomo a red | manual | 1.83d | 2014-09-02 A | 2014-09-03 A |  | 100% |  |  |  |  |
| 86 | 1.2.1.1.5 | Alta tipo de sensor | manual | 1.83d | 2014-09-02 A | 2014-09-03 A |  | 100% |  |  |  |  |
| 87 | 1.2.1.1.6 | Visualización gráficas | manual | 1.83d | 2014-09-02 A | 2014-09-03 A |  | 100% |  |  |  |  |
| 88 | 1.2.1.1.7 | Visualización mapa | manual | 1.83d | 2014-09-02 A | 2014-09-03 A |  | 100% |  |  |  |  |
| 89 | 1.2.1.1.8 | ABM Alarma | manual | 1.83d | 2014-09-02 A | 2014-09-03 A |  | 100% |  |  |  |  |
| 90 | 1.2.1.1.9 | Ubicar obstáculos en el mapa | manual | 1.83d | 2014-09-02 A | 2014-09-03 A |  | 100% |  |  |  |  |
| 91 | 1.2.1.1.10 | Nuevo mote en la red | manual | 1.83d | 2014-09-02 A | 2014-09-03 A |  | 100% |  |  |  |  |
| 92 | 1.2.1.1.11 | AB Cuadros | manual | 1.83d | 2014-09-02 A | 2014-09-03 A |  | 100% |  |  |  |  |
| 93 | 1.2.1.1.12 | Procesar información de los sensores | manual | 1.83d | 2014-09-02 A | 2014-09-03 A |  | 100% |  |  |  |  |
| 94 | 1.2.1.1.13 | Nueva base en red | manual | 1.83d | 2014-09-02 A | 2014-09-03 A |  | 100% |  |  |  |  |
| 95 | 1.2.1.1.14 | Exportar a PDF | manual | 1.83d | 2014-09-02 A | 2014-09-03 A |  | 100% |  |  |  |  |
| 96 | 1.2.1.1.15 | Notificar Usuario | manual | 1.83d | 2014-09-02 A | 2014-09-03 A |  | 100% |  |  |  |  |
| 97 | 1.2.1.2 | D2 - Describir la arquitectura |  | 3h | 2014-09-03 A | 2014-09-04 A | 141, 148, 142, 81 | 100% |  | Diego S; Ana Clara E; Fabricio G; Juan C; Santiago B | 15h | 15h |
| 98 | 1.2.1.3 | D3 - Comunicar el diseño a los implementadores |  | 3h | 2014-09-04 A | 2014-09-04 A | 81, 97 | 100% |  | Diego S; Ana Clara E; Fabricio G; Juan C; Santiago B; Fernando P; Mathias B; Mathias F; Rolando L; Santiago F | 30h | 30h |
| 99 | 1.2.1.4 | D4 - Diseñar base de datos |  | 3h | 2014-09-04 A | 2014-09-04 A | 97, 81, 142 | 100% |  | Diego S | 3h | 3h |
| 100 | 1.2.2 | **Reuniones de Apoyo** |  | 0.17d | 2014-09-02 A | 2014-09-02 A |  | 100% |  |  | 3h | 3h |
| 101 | 1.2.2.1 | E1.1 - Clase para Administradores |  | 1h | 2014-09-02 A | 2014-09-02 A |  | 100% |  | Ignacio A | 1h | 1h |
| 102 | 1.2.2.2 | E1.2 Clase para Arquitectos |  | 1h | 2014-09-02 A | 2014-09-02 A |  | 100% |  | Diego S | 1h | 1h |
| 103 | 1.2.2.3 | E1.3 Clase para Resp. V&V |  | 1h | 2014-09-02 A | 2014-09-02 A |  | 100% |  | Fernando P | 1h | 1h |

Notes:
- 99: Con algun esp técnico

| ID | WBS | Task | Type | Duration | Start | Finish | Predecessors | Complete | Resources | Work | Actual work |
| --- | --- | --- | --- | --- | --- | --- | --- | --- | --- | --- | --- |
| 104 | 1.2.3 | **Gestión de Calidad** |  | 5d | 2014-09-02 A | 2014-09-04 A |  | 100% |  | 18h | 18h |
| 105 | 1.2.3.1 | Q1 - Identificar las propiedades de calidad |  | 3h | 2014-09-02 A | 2014-09-03 A | 142, 140, 141, 2 | 100% | Oscar M | 3h | 3h |
| 106 | 1.2.3.2 | Q2 - Plan de calidad |  | 5h | 2014-09-03 A | 2014-09-04 A | 141, 142, 81 | 100% | Oscar M | 5h | 5h |
| 107 | 1.2.3.3 | Q5 - Revisar las entregas |  | 5h | 2014-09-02 A | 2014-09-02 A |  | 100% | Oscar M | 5h | 5h |
| 108 | 1.2.3.4 | Q6 - Revisar el ajuste del proceso |  | 2h | 2014-09-04 A | 2014-09-04 A | 106 | 100% | Oscar M | 2h | 2h |
| 109 | 1.2.3.5 | Q7 - Evaluar la calidad de los productos |  | 3h | 2014-09-04 A | 2014-09-04 A | 106 | 100% | Oscar M | 3h | 3h |
| 110 | 1.2.4 | **Gestión de Configuración** |  | 2d | 2014-09-02 A | 2014-09-03 A |  | 100% |  | 57h | 57h |
| 111 | 1.2.4.1 | C1 - Planificar la configuración del SCM |  | 3h | 2014-09-02 A | 2014-09-02 A | 2 | 100% | Emiliano T | 3h | 3h |
| 112 | 1.2.4.2 | C2 - Definir la línea base del proyecto |  | 5h | 2014-09-02 A | 2014-09-02 A | 2 | 100% | Emiliano T; Mathias B; Mathias F; Oscar M; Rolando L; Santiago F | 30h | 30h |
| 113 | 1.2.4.3 | Plan de Configuración | milestone | 0d | 2014-09-02 A | 2014-09-02 A | 111, 112 | 100% |  |  |  |
| 114 | 1.2.4.4 | C4 - Definir el ambiente controlado |  | 4h | 2014-09-02 A | 2014-09-03 A | 113 | 100% | Emiliano T; Mathias B; Mathias F; Rolando L; Santiago F | 20h | 20h |
| 115 | 1.2.4.5 | C5 - Control de cambios |  | 4h | 2014-09-02 A | 2014-09-03 A | 2, 113 | 100% | Emiliano T | 4h | 4h |
| 116 | 1.2.5 | **Gestión de Proyecto** |  | 5.17d | 2014-09-02 A | 2014-09-04 A |  | 100% |  | 107h | 107h |
| 117 | 1.2.5.1 | G1 - Planificar el proyecto |  | 4h | 2014-09-04 A | 2014-09-04 A | 125, 124, 113, 106, 140, 2, 131, 141, 142 | 100% | Ignacio A | 4h | 4h |
| 118 | 1.2.5.2 | G13 - Evaluar la fase |  | 4h | 2014-09-02 A | 2014-09-02 A |  | 100% | Ignacio A | 4h | 4h |
| 119 | 1.2.5.3 | G15 - Revisión técnica y administrativa |  | 1h | 2014-09-02 A | 2014-09-02 A | 121, 126, 107 | 100% | Diego S; Fernando P; Oscar M; Ignacio A | 4h | 4h |
| 120 | 1.2.5.4 | G16 - Reunión de responsables por área |  | 1h | 2014-09-02 A | 2014-09-02 A |  | 100% | Diego S; Emiliano T; Fernando P; Ignacio A; Oscar M; Santiago B; Santiago F | 7h | 7h |
| 121 | 1.2.5.5 | Plan de la Iteración | milestone | 0d | 2014-09-02 A | 2014-09-02 A | 120 | 100% |  |  |  |
| 122 | 1.2.5.6 | G18 - Presentación al director de proyecto |  | 1h | 2014-09-02 A | 2014-09-02 A |  | 100% | Ignacio A | 1h | 1h |
| 123 | 1.2.5.7 | G2 - Seguimiento del proyecto |  | 5h | 2014-09-02 A | 2014-09-02 A |  | 100% | Diego S; Ignacio A | 10h | 10h |
| 124 | 1.2.5.8 | G3 - Estimaciones y mediciones |  | 5h | 2014-09-02 A | 2014-09-02 A |  | 100% | Ana Clara E; Diego S; Fabricio G; Ignacio A; Juan C; Santiago B | 30h | 30h |
| 125 | 1.2.5.9 | G4 - Gestión de riesgo |  | 3h | 2014-09-02 A | 2014-09-02 A | 2, 124, 123 | 100% | Ignacio A | 3h | 3h |
| 126 | 1.2.5.10 | G5 - Registrar esfuerzo |  | 1h | 2014-09-02 A | 2014-09-02 A |  | 100% | TODOS | 1h | 1h |
| 127 | 1.2.5.11 | G6 - Reunión de equipo |  | 1h | 2014-09-02 A | 2014-09-02 A |  | 100% | TODOS | 1h | 1h |
| 128 | 1.2.5.12 | G7 - Elaborar Acta de reunión de equipo |  | 1h | 2014-09-02 A | 2014-09-02 A | 127 | 100% | Diego S | 1h | 1h |
| 129 | 1.2.5.13 | G8 - Reunión de seguimiento |  | 1h | 2014-09-02 A | 2014-09-02 A |  | 100% | Diego S; Fernando P; Ignacio A; Oscar M; Santiago B | 5h | 5h |
| 130 | 1.2.5.14 | G9 - Ajustar y controlar el desarrollo |  | 4h | 2014-09-02 A | 2014-09-03 A | 2, 121, 123 | 100% | Diego S; Fabricio G; Fernando P; Juan C; Mathias B; Mathias F; Rolando L; Santiago B; Santiago F | 36h | 36h |
| 131 | 1.2.5.15 | Plan de Desarrollo | milestone | 0d | 2014-09-03 A | 2014-09-03 A | 130 | 100% |  |  |  |

Notes:
- 105: Lo podrian ayudar los asistentes
- 106: Lo podrian ayudar los asistentes
- 107: Lo podrian ayudar los asistentes
- 108: Lo podrian ayudar los asistentes
- 109: Lo podrian ayudar los asistentes
- 117: Con ayuda de los responsables
- 118: Con todo el resto
- 119: Con cecilia
- 122: Podria ayudar cualquiera
- 125: Podria ayudar cualquiera

| ID | WBS | Task | Type | Duration | Start | Finish | Predecessors | Complete | Resources | Work | Actual work |
| --- | --- | --- | --- | --- | --- | --- | --- | --- | --- | --- | --- |
| 132 | 1.2.6 | **Implementación** |  | 6.83d | 2014-09-02 A | 2014-09-05 A |  | 100% |  | 274h | 274h |
| 133 | 1.2.6.1 | I1 - Definir estándares de documentación técnica |  | 2h | 2014-09-02 A | 2014-09-02 A | 2 | 100% | Mathias B; Mathias F; Rolando L; Santiago F | 8h | 8h |
| 134 | 1.2.6.2 | I2 - Implementar el prototipo |  | 2.17d | 2014-09-04 A | 2014-09-05 A | 81, 131, 121, 97 | 100% | Mathias B; Mathias F; Rolando L; Santiago F; Diego S; Fabricio G; Fernando P; Juan C; Santiago B | 117h | 117h |
| 135 | 1.2.6.3 | I3 - Corregir la implementación |  | 0.67d | 2014-09-02 A | 2014-09-02 A |  | 100% | Mathias B; Mathias F; Rolando L; Santiago F; Diego S; Fabricio G; Fernando P; Juan C; Santiago B | 36h | 36h |
| 136 | 1.2.6.4 | I4 - Planificar la integración de la iteración |  | 4h | 2014-09-04 A | 2014-09-04 A | 142, 81, 97 | 100% | Mathias B; Mathias F; Rolando L; Santiago F; Diego S; Fabricio G; Fernando P; Juan C; Santiago B | 36h | 36h |
| 137 | 1.2.6.5 | I5 - Integrar el sistema (del prototipo) |  | 1.5d | 2014-09-03 A | 2014-09-04 A | 81, 131 | 100% | Diego S; Mathias B; Mathias F; Rolando L; Santiago F | 45h | 45h |
| 138 | 1.2.6.6 | I7 - Verificación unitaria del módulo |  | 0.67d | 2014-09-04 A | 2014-09-04 A | 142, 150, 151 | 100% | Fabricio G; Fernando P; Juan C; Mathias B; Mathias F; Rolando L; Santiago B; Santiago F | 32h | 32h |
| 139 | 1.2.7 | **Requerimientos** |  | 1.5d | 2014-09-02 A | 2014-09-02 A |  | 100% |  | 47h | 47h |
| 140 | 1.2.7.1 | R1 - Reunión de requerimientos |  | 1h | 2014-09-02 A | 2014-09-02 A |  | 100% | Mathias B; Mathias F; Rolando L; Santiago B; Santiago F | 5h | 5h |
| 141 | 1.2.7.2 | R2 - Especificar requerimientos |  | 2h | 2014-09-02 A | 2014-09-02 A | 140 | 100% | Ana Clara E; Fabricio G; Juan C; Santiago B | 8h | 8h |
| 142 | 1.2.7.3 | R3 - Especificar casos de uso |  | 3h | 2014-09-02 A | 2014-09-02 A | 141 | 100% | Ana Clara E; Fabricio G; Juan C; Santiago B | 12h | 12h |
| 143 | 1.2.7.4 | R4 - Priorizar casos de uso |  | 1h | 2014-09-02 A | 2014-09-02 A | 141 | 100% | Ana Clara E; Fabricio G; Juan C; Santiago B; Diego S | 5h | 5h |
| 144 | 1.2.7.5 | Descripción de la arquitectura (vista de CU) | milestone | 0d | 2014-09-02 A | 2014-09-02 A | 143 | 100% |  |  |  |
| 145 | 1.2.7.6 | R5 - Validación con el cliente |  | 1h | 2014-09-02 A | 2014-09-02 A | 141 | 100% | Diego S | 1h | 1h |
| 146 | 1.2.7.7 | R6 - Definir pautas para la interfaz de usuario |  | 5h | 2014-09-02 A | 2014-09-02 A | 140 | 100% | Fabricio G; Juan C | 10h | 10h |
| 147 | 1.2.7.8 | R7 - Definir alcance del sistema |  | 1h | 2014-09-02 A | 2014-09-02 A | 141, 142, 146, 148 | 100% | Diego S; Ignacio A | 2h | 2h |
| 148 | 1.2.7.9 | R8 - Definir glosario |  | 1h | 2014-09-02 A | 2014-09-02 A |  | 100% | Ana Clara E; Fabricio G; Juan C; Santiago B | 4h | 4h |
| 149 | 1.2.8 | **Verificación** |  | 12.67d | 2014-09-02 A | 2014-09-08 A |  | 100% |  | 133h | 133h |
| 150 | 1.2.8.1 | V1 - Planificar la verificación |  | 5h | 2014-09-02 A | 2014-09-03 A | 2, 142 | 100% | Fernando P | 5h | 5h |
| 151 | 1.2.8.2 | V3 - Planificar las pruebas de la iteración |  | 5h | 2014-09-03 A | 2014-09-04 A | 81, 142, 150, 2, 131 | 100% | Diego S; Fernando P | 10h | 10h |
| 152 | 1.2.8.3 | V4 - Especificar los casos de prueba |  | 1.5d | 2014-09-04 A | 2014-09-05 A | 141, 142, 150, 151 | 100% | Fernando P | 9h | 9h |
| 153 | 1.2.8.4 | V5 - Verificar documento |  | 5h | 2014-09-04 A | 2014-09-04 A | 142, 150, 151 | 100% | Fernando P | 5h | 5h |
| 154 | 1.2.8.5 | V6 - Generar entorno de prueba |  | 4h | 2014-09-02 A | 2014-09-02 A |  | 100% | Diego S; Emiliano T | 8h | 8h |
| 155 | 1.2.8.6 | V7 - Ejecutar las pruebas |  | 2d | 2014-09-05 A | 2014-09-08 A | 131, 150, 151, 152 | 100% | Fabricio G; Fernando P; Juan C; Mathias B; Mathias F; Rolando L; Santiago B; Santiago F | 96h | 96h |

Notes:
- 135: Podria ayudar algun asistente de verificación
- 140: y algunos analistas
- 141: Deben ser verificados por Pedro
- 142: Deben ser verificados por Pedro
- 143: Deben ser verificados por Pedro
- 147: Con algun analista
- 151: Podria ayduar algun asistente
- 152: Podria ayduar algun asistente
- 153: Podria ayduar algun asistente

| ID | WBS | Task | Type | Duration | Start | Finish | Predecessors | Complete | Actual start | Actual finish | Resources | Work | Actual work |
| --- | --- | --- | --- | --- | --- | --- | --- | --- | --- | --- | --- | --- | --- |
| 156 | 1.2.9 | **Comunicación** |  | 2.17d | 2014-09-02 A | 2014-09-03 A |  | 100% |  |  |  | 10h | 10h |
| 157 | 1.2.9.1 | CM4 - Gestión de "Lecciones Aprendidas" |  | 1h | 2014-09-02 A | 2014-09-02 A | 123, 128 | 100% |  |  | Ignacio A | 1h | 1h |
| 158 | 1.2.9.2 | CM2 - Definición del documento de "Visión" |  | 1h | 2014-09-02 A | 2014-09-02 A | 141, 142 | 100% |  |  | Ana Clara E; Fabricio G; Juan C; Santiago B | 4h | 4h |
| 159 | 1.2.9.3 | CM3 - Elaboración del documento "Registro de Rastreo" |  | 1h | 2014-09-03 A | 2014-09-03 A | 81, 141, 142, 150 | 100% |  |  | Ana Clara E; Fabricio G; Juan C; Santiago B; Diego S | 5h | 5h |
| 160 | 2 | Fin de Fase Inicial | milestone, manual | 0d | 2014-09-15 | 2014-09-15 |  |  |  |  |  |  |  |
| 161 | 3 | **Fase Elaboración** |  | 51.17d | 2014-09-16 | 2014-10-13 A |  | 100% | 2014-08-15 |  |  | 2326.5h | 2326.5h |
| 162 | 3.1 | **Iteración 1** |  | 25.5d | 2014-09-16 | 2014-09-29 |  | 100% | 2014-09-15 | 2014-09-30 |  | 1390.5h | 1390.5h |
| 163 | 3.1.1 | **Diseño** |  | 1.83d? | 2014-09-16 A | 2014-09-16 |  | 100% |  | 2014-09-28 |  | 6h | 6h |
| 164 | 3.1.1.1 | **D1 - Diseñar casos de uso** |  | 1.83d? | 2014-09-16 A | 2014-09-16 A |  | 100% |  |  |  |  |  |
| 165 | 3.1.1.1.1 | D1 - Diseñar Nuevos | manual | 4h | 2014-09-16 A | 2014-09-16 A |  | 100% |  |  |  |  |  |
| 166 | 3.1.1.1.2 | D1 - Corregir diseños | manual | 4h | 2014-09-16 A | 2014-09-16 A |  | 100% |  |  |  |  |  |
| 167 | 3.1.1.2 | D1 - Modelo de Diseño | manual | 2h | 2014-09-28 A | 2014-09-28 A | 164 | 100% |  |  | Diego S | 2h | 2h |
| 168 | 3.1.1.3 | D2 - Describir la arquitectura (Corregir) | manual | 2h | 2014-09-16 A | 2014-09-16 A |  | 100% |  |  | Diego S | 2h | 2h |
| 169 | 3.1.1.4 | D3 - Comunicar el diseño a los implementadores | manual | 2h | 2014-09-16 A | 2014-09-16 A |  | 100% |  |  |  |  |  |
| 170 | 3.1.1.5 | D4 - Diseñar base de datos | manual | 2h | 2014-09-16 A | 2014-09-16 A |  | 100% |  |  | Diego S | 2h | 2h |
| 171 | 3.1.2 | **Gestión de Calidad** |  | 1.83d? | 2014-09-16 A | 2014-09-16 |  | 100% |  | 2014-09-29 |  | 24h | 24h |
| 172 | 3.1.2.1 | Q3 - Evaluar y ajustar el plan de SQ | manual | 2h | 2014-09-16 A | 2014-09-16 A |  | 100% |  |  |  |  |  |
| 173 | 3.1.2.2 | **Q4 - Revisión técnica formal** |  | 1.83d? | 2014-09-16 A | 2014-09-16 A |  | 100% |  |  |  | 4h | 4h |
| 174 | 3.1.2.2.1 | Q4 - RTF Descripción de la arquitectura | manual | 2h | 2014-09-16 A | 2014-09-16 A |  | 100% |  |  | Diego S; Oscar M | 4h | 4h |
| 175 | 3.1.2.3 | Q5 - Revisar las entregas | manual | 5h | 2014-09-16 A | 2014-09-16 A |  | 100% |  |  | Oscar M | 5h | 5h |
| 176 | 3.1.2.4 | Q5 - Entrega Semanal Semana 1 | milestone, manual | 0h | 2014-09-22 A | 2014-09-22 A | 175 | 100% |  |  | Oscar M |  |  |
| 177 | 3.1.2.5 | Q5 - Entrega Semanal Semana 2 | milestone, manual | 0h | 2014-09-29 A | 2014-09-29 A | 175 | 100% |  |  | Oscar M |  |  |
| 178 | 3.1.2.6 | **Q6 - Revisar el ajuste del proceso** |  | 1.67d | 2014-09-16 A | 2014-09-16 A |  | 100% |  |  | Oscar M | 13h | 13h |
| 179 | 3.1.2.6.1 | Q6 - Revisión de requerimientos | manual | 1h | 2014-09-16 A | 2014-09-16 A |  | 100% |  |  | Oscar M | 1h | 1h |
| 180 | 3.1.2.6.2 | Q6 - Revisión de diseño preliminar | manual | 1h | 2014-09-16 A | 2014-09-16 A |  | 100% |  |  | Oscar M | 1h | 1h |
| 181 | 3.1.2.6.3 | Q6 - Revisión de Plan V&V | manual | 1h | 2014-09-16 A | 2014-09-16 A |  | 100% |  |  | Oscar M | 1h | 1h |
| 182 | 3.1.2.6.4 | Q6 - Revisión de SCM | manual | 1h | 2014-09-16 A | 2014-09-16 A |  | 100% |  |  | Oscar M | 1h | 1h |
| 183 | 3.1.2.6.5 | Q6 - Revisión de Gestión | manual | 1h | 2014-09-16 A | 2014-09-16 A |  | 100% |  |  | Oscar M | 1h | 1h |
| 184 | 3.1.2.7 | Q7 - Evaluar la calidad de los productos | manual | 2h | 2014-09-16 A | 2014-09-16 A |  | 100% |  |  | Oscar M | 2h | 2h |
| 185 | 3.1.2.8 | Informe de revisión de SQA (1) | milestone, manual | 0d | 2014-09-22 A | 2014-09-22 A | 178, 184 | 100% |  |  | Oscar M |  |  |

| ID | WBS | Task | Type | Duration | Start | Finish | Predecessors | Complete | Actual finish | Resources | Work | Actual work |
| --- | --- | --- | --- | --- | --- | --- | --- | --- | --- | --- | --- | --- |
| 186 | 3.1.3 | **Gestión de Configuración** |  | 1.83d? | 2014-09-16 A | 2014-09-16 |  | 100% | 2014-09-28 |  | 9.5h | 9.5h |
| 187 | 3.1.3.1 | C2 - Definir la línea base del proyecto | manual | 2h | 2014-09-16 A | 2014-09-16 A |  | 100% |  | Emiliano T | 2h | 2h |
| 188 | 3.1.3.2 | C3 - Seguimiento de la línea base | manual | 2h | 2014-09-16 A | 2014-09-16 A |  | 100% |  | Emiliano T | 2h | 2h |
| 189 | 3.1.3.3 | C5 - Control de cambios | manual | 1h | 2014-09-16 A | 2014-09-16 A |  | 100% |  | Emiliano T | 1h | 1h |
| 190 | 3.1.3.4 | C5 - Registro de versiones (1) | milestone, manual | 0d | 2014-09-21 A | 2014-09-21 A |  | 100% |  | Emiliano T |  |  |
| 191 | 3.1.3.5 | C5 - Registro de versiones (2) | milestone, manual | 0d | 2014-09-28 A | 2014-09-28 A |  | 100% |  | Emiliano T |  |  |
| 192 | 3.1.3.6 | C5 - Gestión de cambios | milestone, manual | 0d | 2014-09-28 A | 2014-09-28 A |  | 100% |  | Emiliano T |  |  |
| 193 | 3.1.3.7 | C7 - Especificación de la Liberación (1) | manual | 1h | 2014-09-16 A | 2014-09-16 A |  | 100% |  | Emiliano T; Diego S | 2h | 2h |
| 194 | 3.1.3.8 | C7 - Especificación de la Liberación (2) | manual | 1h | 2014-09-16 A | 2014-09-16 A |  | 100% |  | Emiliano T; Diego S | 2h | 2h |
| 195 | 3.1.3.9 | C8 - Escribir las notas de la versión | manual | 0.5h | 2014-09-16 A | 2014-09-16 A |  | 100% |  | Emiliano T | 0.5h | 0.5h |
| 196 | 3.1.4 | **Gestión de Proyecto** |  | 1.83d? | 2014-09-16 A | 2014-09-16 |  | 100% | 2014-09-28 |  | 11h | 11h |
| 197 | 3.1.4.1 | G10 - Evaluar y ajustar el plan de proyecto | manual | 2h | 2014-09-16 A | 2014-09-16 A |  | 100% |  | Ignacio A | 2h | 2h |
| 198 | 3.1.4.2 | G14 - Reunión evaluativa con el director del proyecto | manual | 1h | 2014-09-23 A | 2014-09-23 A |  | 100% |  | Ignacio A | 1h | 1h |
| 199 | 3.1.4.3 | G14 - Acta de reunión evaluativa con el director | milestone, manual | 0h | 2014-09-23 A | 2014-09-23 A | 198 | 100% |  | Ignacio A |  |  |
| 200 | 3.1.4.4 | G15 - Revisión técnica y administrativa | manual | 2h | 2014-09-16 A | 2014-09-16 A |  | 100% |  |  |  |  |
| 201 | 3.1.4.5 | G16 - Reunión de responsables por área | manual | 1h | 2014-09-16 A | 2014-09-16 A |  | 100% |  |  |  |  |
| 202 | 3.1.4.6 | G2 - Seguimiento del proyecto | manual | 1.83d | 2014-09-16 A | 2014-09-16 A |  | 100% |  |  |  |  |
| 203 | 3.1.4.7 | G2 - Informe de situación del proyecto (1) | milestone, manual | 0d | 2014-09-21 A | 2014-09-21 A | 202 | 100% |  | Ignacio A |  |  |
| 204 | 3.1.4.8 | G2 - Informe de situación del proyecto (2) | milestone, manual | 0d | 2014-09-28 A | 2014-09-28 A | 202 | 100% |  | Ignacio A |  |  |
| 205 | 3.1.4.9 | G3 - Estimaciones y mediciones | manual | 2h | 2014-09-16 A | 2014-09-16 A |  | 100% |  | Ignacio A | 2h | 2h |
| 206 | 3.1.4.10 | G4 - Gestión de riesgos | manual | 2h | 2014-09-16 A | 2014-09-16 A |  | 100% |  | Ignacio A | 2h | 2h |
| 207 | 3.1.4.11 | G5 - Registrar esfuerzo | manual | 1.83d | 2014-09-16 A | 2014-09-16 A |  | 100% |  |  |  |  |
| 208 | 3.1.4.12 | G6 - Reunión de equipo | manual | 1h | 2014-09-26 A | 2014-09-26 A |  | 100% |  | TODOS | 1h | 1h |
| 209 | 3.1.4.13 | G7 - Elaborar acta de reunión de equipo | manual | 1h | 2014-09-26 A | 2014-09-26 A | 208 | 100% |  | Diego S | 1h | 1h |
| 210 | 3.1.4.14 | G8 - Reunión de seguimiento | manual | 1h | 2014-09-16 A | 2014-09-16 A |  | 100% |  |  |  |  |
| 211 | 3.1.4.15 | G9 - Ajustar y controlar el desarrollo | manual | 2h | 2014-09-16 A | 2014-09-16 A |  | 100% |  | Diego S | 2h | 2h |
| 212 | 3.1.4.16 | G9 - Plan de desarrollo (1) | milestone, manual | 0h | 2014-09-21 A | 2014-09-21 A | 211 | 100% |  | Diego S |  |  |
| 213 | 3.1.4.17 | G9 - Plan de desarrollo (2) | milestone, manual | 0h | 2014-09-28 A | 2014-09-28 A | 211 | 100% |  | Diego S |  |  |
| 214 | 3.1.4.18 | Plan de la Iteración | milestone, manual | 0d | 2014-09-28 A | 2014-09-28 A |  | 100% |  | Ignacio A |  |  |

| ID | WBS | Task | Type | Duration | Start | Finish | Predecessors | Complete | Actual start | Actual finish | Resources | Work | Actual work |
| --- | --- | --- | --- | --- | --- | --- | --- | --- | --- | --- | --- | --- | --- |
| 215 | 3.1.5 | **Plan de Implantación** |  | 1.83d? | 2014-09-16 A | 2014-09-16 A |  | 100% |  |  |  | 2h | 2h |
| 216 | 3.1.5.1 | P9 - Definir estándares de documentación de usuario | manual | 2h | 2014-09-16 A | 2014-09-16 A |  | 100% |  |  | Ana Clara E | 2h | 2h |
| 217 | 3.1.6 | **Implementación** |  | 1.83d? | 2014-09-16 | 2014-09-16 |  | 100% | 2014-09-15 | 2014-09-30 |  | 1281h | 1281h |
| 218 | 3.1.6.1 | I3 - Corregir la implementación | manual | 1.83d | 2014-09-16 A | 2014-09-16 A |  | 100% |  |  |  |  |  |
| 219 | 3.1.6.2 | I4 - Planificar la integración de la iteración | manual | 1.83d | 2014-09-16 A | 2014-09-16 A |  | 100% |  |  | Implementadores | 11h | 11h |
| 220 | 3.1.6.3 | I5 - Integrar el sistema | manual | 1.83d | 2014-09-16 A | 2014-09-16 A |  | 100% |  |  |  |  |  |
| 221 | 3.1.6.4 | I6 - Documentación técnica | manual | 1.83d | 2014-09-16 A | 2014-09-16 A |  | 100% |  |  |  |  |  |
| 222 | 3.1.6.5 | I7 - Verificación unitaria de módulo | manual | 1.83d | 2014-09-16 A | 2014-09-16 A |  | 100% |  |  |  |  |  |
| 223 | 3.1.6.6 | I16 - Definir los Estilos | manual | 1.83d | 2014-09-16 A | 2014-09-16 A |  | 100% |  |  |  |  |  |
| 224 | 3.1.6.7 | I09 - Definir Modelo de implementación | manual | 1.83d | 2014-09-16 A | 2014-09-16 A |  | 100% |  |  | Implementadores; Diego S | 20h | 20h |
| 225 | 3.1.6.8 | Modelo de implementación | milestone, manual | 0h | 2014-09-16 A | 2014-09-16 A | 224 | 100% |  |  | Implementadores |  |  |
| 226 | 3.1.6.9 | I14 - Crear y configurar Base de Conocimiento | manual | 1.83d | 2014-09-16 A | 2014-09-16 A |  | 100% |  |  |  |  |  |
| 227 | 3.1.6.10 | Creación de esqueleto de aplicación | manual | 0.67d | 2014-09-15 A | 2014-09-15 A |  | 100% |  |  | Santiago F; Mathias B; Emiliano T; Diego S | 16h | 16h |
| 228 | 3.1.6.11 | Creación de la base de datos | manual | 0.67d | 2014-09-16 A | 2014-09-16 A |  | 100% |  |  | Santiago F; Mathias F; Diego S | 12h | 12h |
| 229 | 3.1.6.12 | **CU Login/Logout** |  | 3d | 2014-09-16 A | 2014-09-17 | 18 | 100% |  | 2014-09-18 |  | 50h | 50h |
| 230 | 3.1.6.12.1 | Lógica | manual | 1.67d | 2014-09-16 A | 2014-09-16 A |  | 100% |  |  | Santiago B; Emiliano T | 16h | 16h |
| 231 | 3.1.6.12.2 | Presentación | manual | 1.67d | 2014-09-16 A | 2014-09-16 A |  | 100% |  |  | Juan C; Fabricio G | 16h | 16h |
| 232 | 3.1.6.12.3 | Verificaciónes unitarias | manual | 1.83d | 2014-09-18 A | 2014-09-18 A |  | 100% |  |  | Santiago B; Emiliano T | 18h | 18h |
| 233 | 3.1.6.13 | **CU Alta Técnico** |  | 3d | 2014-09-16 A | 2014-09-17 | 18 | 100% |  | 2014-09-18 |  | 50h | 50h |
| 234 | 3.1.6.13.1 | Lógica | manual | 1.67d | 2014-09-16 A | 2014-09-16 A |  | 100% |  |  | Santiago B; Emiliano T | 16h | 16h |
| 235 | 3.1.6.13.2 | Presentación | manual | 1.67d | 2014-09-16 A | 2014-09-16 A |  | 100% |  |  | Juan C; Fabricio G | 16h | 16h |
| 236 | 3.1.6.13.3 | Verificaciónes unitarias | manual | 1.83d | 2014-09-18 A | 2014-09-18 A |  | 100% |  |  | Santiago B; Emiliano T | 18h | 18h |
| 237 | 3.1.6.14 | **CU Alta Agrónomo** |  | 5d | 2014-09-16 A | 2014-09-18 | 18 | 100% |  | 2014-09-22 |  | 50h | 50h |
| 238 | 3.1.6.14.1 | Lógica | manual | 1.67d | 2014-09-16 A | 2014-09-16 A |  | 100% |  |  | Santiago B; Emiliano T | 16h | 16h |
| 239 | 3.1.6.14.2 | Presentación | manual | 1.67d | 2014-09-16 A | 2014-09-16 A |  | 100% |  |  | Mathias F; Santiago F | 16h | 16h |
| 240 | 3.1.6.14.3 | Verificaciónes unitarias | manual | 1.83d | 2014-09-22 A | 2014-09-22 A |  | 100% |  |  | Emiliano T; Santiago B | 18h | 18h |

| ID | WBS | Task | Type | Duration | Start | Finish | Predecessors | Complete | Actual finish | Resources | Work | Actual work |
| --- | --- | --- | --- | --- | --- | --- | --- | --- | --- | --- | --- | --- |
| 241 | 3.1.6.15 | **CU Visualizar Capas de una Red** |  | 7d | 2014-09-16 A | 2014-09-19 | 18, 36 | 100% | 2014-09-24 |  | 66h | 66h |
| 242 | 3.1.6.15.1 | Lógica | manual | 1.67d | 2014-09-16 A | 2014-09-16 A |  | 100% |  | Emiliano T; Santiago B | 16h | 16h |
| 243 | 3.1.6.15.2 | Presentación | manual | 1.67d | 2014-09-16 A | 2014-09-16 A |  | 100% |  | Rolando L; Mathias B; Juan C; Fabricio G | 32h | 32h |
| 244 | 3.1.6.15.3 | Verificaciónes unitarias | manual | 1.83d | 2014-09-24 A | 2014-09-24 A |  | 100% |  | Emiliano T; Santiago B | 18h | 18h |
| 245 | 3.1.6.16 | **CU Alta Red** |  | 5d | 2014-09-16 A | 2014-09-18 | 18 | 100% | 2014-09-22 |  | 100h | 100h |
| 246 | 3.1.6.16.1 | Lógica SA | manual | 1.67d | 2014-09-16 A | 2014-09-16 A |  | 100% |  | Santiago B; Emiliano T | 16h | 16h |
| 247 | 3.1.6.16.2 | Lógica Daemon | manual | 1.67d | 2014-09-16 A | 2014-09-16 A |  | 100% |  | Santiago F; Mathias F | 16h | 16h |
| 248 | 3.1.6.16.3 | Presentación | manual | 1.67d | 2014-09-16 A | 2014-09-16 A |  | 100% |  | Rolando L; Mathias B; Juan C; Fabricio G | 32h | 32h |
| 249 | 3.1.6.16.4 | Verificaciónes unitarias | manual | 1.83d | 2014-09-22 A | 2014-09-22 A |  | 100% |  | Santiago F; Santiago B; Mathias F; Emiliano T | 36h | 36h |
| 250 | 3.1.6.17 | **CU Ingresar Mote a Red** |  | 7d | 2014-09-22 A | 2014-09-25 | 18 | 100% | 2014-09-30 |  | 100h | 100h |
| 251 | 3.1.6.17.1 | Lógica SA | manual | 1.67d | 2014-09-22 A | 2014-09-22 A |  | 100% |  | Emiliano T; Santiago B | 16h | 16h |
| 252 | 3.1.6.17.2 | Lógica Daemon | manual | 1.67d | 2014-09-22 A | 2014-09-22 A |  | 100% |  | Mathias F; Santiago F | 16h | 16h |
| 253 | 3.1.6.17.3 | Presentación | manual | 1.67d | 2014-09-22 A | 2014-09-22 A |  | 100% |  | Rolando L; Mathias B; Juan C; Fabricio G | 32h | 32h |
| 254 | 3.1.6.17.4 | Verificaciónes unitarias | manual | 1.83d | 2014-09-30 A | 2014-09-30 A |  | 100% |  | Santiago F; Santiago B; Mathias F; Emiliano T | 36h | 36h |
| 255 | 3.1.6.18 | **CU Recibir info de mote** |  | 3d | 2014-09-16 A | 2014-09-17 | 18 | 100% | 2014-09-18 | Mathias F; Santiago F | 42h | 42h |
| 256 | 3.1.6.18.1 | Lógica | manual | 1.67d | 2014-09-16 A | 2014-09-16 A |  | 100% |  | Mathias F; Santiago F | 16h | 16h |
| 257 | 3.1.6.18.2 | Verificaciónes unitarias | manual | 1.83d | 2014-09-18 A | 2014-09-18 A |  | 100% |  |  |  |  |
| 258 | 3.1.6.19 | **CU Sistema reconoce nuevo mote en red** |  | 5d | 2014-09-16 A | 2014-09-18 | 18 | 100% | 2014-09-22 | Mathias F; Santiago F | 78h | 78h |
| 259 | 3.1.6.19.1 | Lógica | manual | 1.67d | 2014-09-16 A | 2014-09-16 A |  | 100% |  | Mathias F; Santiago F | 16h | 16h |
| 260 | 3.1.6.19.2 | Verificaciónes unitarias | manual | 1.83d | 2014-09-22 A | 2014-09-22 A |  | 100% |  | Mathias F; Santiago F | 18h | 18h |
| 261 | 3.1.6.20 | **CU Asignar agrónomo a Red** |  | 7d | 2014-09-22 A | 2014-09-25 | 28 | 100% | 2014-09-30 | Emiliano T; Santiago B | 112h | 112h |
| 262 | 3.1.6.20.1 | Lógica | manual | 1.67d | 2014-09-22 A | 2014-09-22 A |  | 100% |  | Emiliano T; Santiago B | 16h | 16h |
| 263 | 3.1.6.20.2 | Presentación | manual | 1.67d | 2014-09-22 A | 2014-09-22 A |  | 100% |  | Mathias F; Santiago F | 16h | 16h |
| 264 | 3.1.6.20.3 | Verificaciónes unitarias | manual | 1.83d | 2014-09-30 A | 2014-09-30 A |  | 100% |  | Emiliano T; Santiago B | 18h | 18h |

| ID | WBS | Task | Type | Duration | Start | Finish | Predecessors | Complete | Actual start | Actual finish | Resources | Work | Actual work |
| --- | --- | --- | --- | --- | --- | --- | --- | --- | --- | --- | --- | --- | --- |
| 265 | 3.1.6.21 | **Integración** |  | 14.5d | 2014-09-22 A | 2014-09-29 A |  | 100% |  |  |  | 574h | 574h |
| 266 | 3.1.6.21.1 | CU Login/Logout | manual | 7d | 2014-09-22 A | 2014-09-25 A |  | 100% |  |  | Emiliano T; Santiago B | 62h | 62h |
| 267 | 3.1.6.21.2 | CU Alta Técnico | manual | 7d | 2014-09-22 A | 2014-09-25 A |  | 100% |  |  | Emiliano T; Santiago B | 62h | 62h |
| 268 | 3.1.6.21.3 | CU Visualizar Capas de una Red | manual | 5d | 2014-09-24 A | 2014-09-26 A |  | 100% |  |  | Emiliano T; Santiago B | 44h | 44h |
| 269 | 3.1.6.21.4 | CU Alta Red | manual | 7d | 2014-09-22 A | 2014-09-25 A |  | 100% |  |  | Santiago F; Santiago B; Mathias F; Emiliano T | 124h | 124h |
| 270 | 3.1.6.21.5 | CU Ingresar Mote a Red | manual | 5d | 2014-09-24 A | 2014-09-26 A |  | 100% |  |  | Emiliano T; Mathias F; Santiago B; Santiago F | 88h | 88h |
| 271 | 3.1.6.21.6 | CU Recibir info de mote | manual | 7d | 2014-09-22 A | 2014-09-25 A |  | 100% |  |  | Mathias F; Santiago F | 62h | 62h |
| 272 | 3.1.6.21.7 | CU Sistema reconoce nuevo mote en red | manual | 7d | 2014-09-22 A | 2014-09-25 A |  | 100% |  |  | Mathias F; Santiago F | 62h | 62h |
| 273 | 3.1.6.21.8 | CU Asignar agrónomo a Red | manual | 0.67d | 2014-09-29 A | 2014-09-29 A |  | 100% |  |  | Emiliano T; Santiago B | 8h | 8h |
| 274 | 3.1.6.21.9 | CU Alta Agrónomo | manual | 7d | 2014-09-22 A | 2014-09-25 A |  | 100% |  |  | Emiliano T; Santiago B | 62h | 62h |
| 275 | 3.1.6.22 | Margen de error | manual | 1d | 2014-09-29 A | 2014-09-29 A |  | 100% |  |  |  |  |  |
| 276 | 3.1.7 | **Requerimientos** |  | 11.5d | 2014-09-21 A | 2014-09-28 A |  | 100% |  |  |  | 25h | 25h |
| 277 | 3.1.7.1 | R2 - Especificar requerimientos | manual | 1.83d | 2014-09-21 A | 2014-09-22 A |  | 100% |  |  |  |  |  |
| 278 | 3.1.7.2 | R3 - Especificar casos de uso | manual | 2h | 2014-09-21 A | 2014-09-21 A |  | 100% |  |  | Analistas | 2h | 2h |
| 279 | 3.1.7.3 | R4 - Priorizar casos de uso | manual | 1.83d | 2014-09-21 A | 2014-09-22 A |  | 100% |  |  |  |  |  |
| 280 | 3.1.7.4 | R5 - Validación con el cliente | manual | 1.67d | 2014-09-21 A | 2014-09-22 A |  | 100% |  |  | Diego S | 7h | 7h |
| 281 | 3.1.7.5 | R6 - Definir pautas para la interfaz de usuario | manual | 1.67d | 2014-09-21 A | 2014-09-22 A |  | 100% |  |  | Juan C; Fabricio G | 14h | 14h |
| 282 | 3.1.7.6 | R7 - Definir alcance del sistema (1) | manual | 1h | 2014-09-21 A | 2014-09-21 A |  | 100% |  |  | Diego S | 1h | 1h |
| 283 | 3.1.7.7 | R7 - Definir alcance del sistema (2) | manual | 1h | 2014-09-28 A | 2014-09-28 A |  | 100% |  |  | Diego S | 1h | 1h |
| 284 | 3.1.8 | **Verificación** |  | 1.83d? | 2014-09-16 A | 2014-09-16 |  | 100% |  | 2014-09-28 |  | 31h | 31h |
| 285 | 3.1.8.1 | V2 - Evaluar y ajustar el plan de VyV | manual | 1.83d | 2014-09-16 A | 2014-09-16 A |  | 100% |  |  |  |  |  |
| 286 | 3.1.8.2 | V3 - Planificar las pruebas de la iteración | manual | 1.67d | 2014-09-28 A | 2014-09-28 A |  | 100% |  |  | Fernando P | 8h | 8h |
| 287 | 3.1.8.3 | V4 - Especificar los casos de prueba | manual | 4h | 2014-09-16 A | 2014-09-16 A |  | 100% |  |  | Fernando P | 4h | 4h |
| 288 | 3.1.8.4 | **V5 - Verificar documentos** |  | 12.67d | 2014-09-15 | 2014-09-21 A |  | 100% | 2014-09-21 |  |  | 3h | 3h |
| 289 | 3.1.8.4.1 | V5 - Verificar Documento de Requerimientos | manual | 1h | 2014-09-21 A | 2014-09-21 A |  | 100% |  |  | Fernando P | 1h | 1h |
| 290 | 3.1.8.4.2 | V5 - Verificar Modelo de casos de uso | manual | 1h | 2014-09-21 A | 2014-09-21 A |  | 100% |  |  | Fernando P | 1h | 1h |
| 291 | 3.1.8.4.3 | V5 - Verificar Modelo de dominio | manual | 1h | 2014-09-21 A | 2014-09-21 A |  | 100% |  |  | Fernando P | 1h | 1h |
| 292 | 3.1.8.4.4 | V5 - Informe de verificación del documento | milestone, manual | 0d | 2014-09-21 A | 2014-09-21 A | 289, 290, 291 | 100% |  |  | Fernando P |  |  |
| 293 | 3.1.8.5 | V6 - Generar entorno de pruebas | manual | 1.83d | 2014-09-16 A | 2014-09-16 A |  | 100% |  |  |  |  |  |
| 294 | 3.1.8.6 | V7 - Ejecutar las pruebas | manual | 1.83d | 2014-09-16 A | 2014-09-16 A |  | 100% |  |  |  |  |  |
| 295 | 3.1.8.7 | V7 - Reporte de Pruebas (1) | milestone, manual | 0d | 2014-09-21 A | 2014-09-21 A |  | 100% |  |  | Fernando P |  |  |
| 296 | 3.1.8.8 | V7 - Reporte de Pruebas (2) | manual | 1.67d | 2014-09-28 A | 2014-09-28 A |  | 100% |  |  | Fernando P | 8h | 8h |
| 297 | 3.1.8.9 | V9 - Evaluar la verificación | manual | 1.67d | 2014-09-16 A | 2014-09-16 A |  | 100% |  |  | Fernando P | 8h | 8h |

| ID | WBS | Task | Type | Duration | Start | Finish | Predecessors | Complete | Actual start | Actual finish | Resources | Work | Actual work |
| --- | --- | --- | --- | --- | --- | --- | --- | --- | --- | --- | --- | --- | --- |
| 298 | 3.1.9 | **Comunicación** |  | 1.83d? | 2014-09-16 | 2014-09-16 |  | 100% | 2014-09-28 | 2014-09-28 |  | 1h | 1h |
| 299 | 3.1.9.1 | CM4: Gestión de "Lecciones Aprendidas" | manual | 1h | 2014-09-28 A | 2014-09-28 A |  | 100% |  |  | Ignacio A | 1h | 1h |
| 300 | 3.2 | **Iteración 2** |  | 25.5d | 2014-09-30 | 2014-10-13 A |  | 100% | 2014-08-15 |  |  | 936h | 936h |
| 301 | 3.2.1 | **Diseño** |  | 1.83d | 2014-09-30 A | 2014-09-30 A |  | 100% |  |  |  |  |  |
| 302 | 3.2.1.1 | **D1 - Diseñar casos de uso** |  | 1.83d | 2014-09-30 A | 2014-09-30 A |  | 100% |  |  |  |  |  |
| 303 | 3.2.1.1.1 | D1 - Diseñar Nuevos | manual | 1.83d | 2014-09-30 A | 2014-09-30 A |  | 100% |  |  |  |  |  |
| 304 | 3.2.1.1.2 | D1 - Corregir diseños | manual | 1.83d | 2014-09-30 A | 2014-09-30 A |  | 100% |  |  |  |  |  |
| 305 | 3.2.1.2 | D1 - Modelo de Diseño | manual | 1.83d | 2014-09-30 A | 2014-09-30 A |  | 100% |  |  |  |  |  |
| 306 | 3.2.1.3 | D1 - Modelo de Diseño (2) | milestone, manual | 0d | 2014-09-30 A | 2014-09-30 A |  | 100% |  |  | DS |  |  |
| 307 | 3.2.1.4 | D2 - Describir la arquitectura (Corregir) | manual | 1.83d | 2014-09-30 A | 2014-09-30 A |  | 100% |  |  |  |  |  |
| 308 | 3.2.1.5 | D2 - Descripcion de la arquitectura (2) | milestone, manual | 0d | 2014-09-30 A | 2014-09-30 A |  | 100% |  |  | DS |  |  |
| 309 | 3.2.1.6 | D3 - Comunicar el diseño a los implementadores | manual | 1.83d | 2014-09-30 A | 2014-09-30 A |  | 100% |  |  |  |  |  |
| 310 | 3.2.1.7 | D4 - Diseñar base de datos | manual | 1.83d | 2014-09-30 A | 2014-09-30 A |  | 100% |  |  |  |  |  |
| 311 | 3.2.1.8 | D4 - Modelo de datos (2) | milestone, manual | 0d | 2014-09-30 A | 2014-09-30 A |  | 100% |  |  | DS |  |  |
| 312 | 3.2.2 | **Gestión de Calidad** |  | 1.83d? | 2014-09-30 | 2014-09-30 |  | 100% | 2014-09-29 | 2014-10-13 |  |  |  |
| 313 | 3.2.2.1 | Q3 - Evaluar y ajustar el plan de SQ | manual | 1.83d | 2014-09-30 A | 2014-09-30 A |  | 100% |  |  |  |  |  |
| 314 | 3.2.2.2 | **Q4 - Revisión técnica formal** |  | 1.83d | 2014-09-30 A | 2014-09-30 A |  | 100% |  |  |  |  |  |
| 315 | 3.2.2.2.1 | Q4 - RTF Gestion (1) | manual | 1.83d | 2014-09-30 A | 2014-09-30 A |  | 100% |  |  |  |  |  |
| 316 | 3.2.2.2.2 | Q4 - RTF Diseño preliminar (1) | manual | 1.83d | 2014-09-30 A | 2014-09-30 A |  | 100% |  |  |  |  |  |
| 317 | 3.2.2.3 | Q5 - Revisar las entrega | manual | 1.83d | 2014-09-30 A | 2014-09-30 A |  | 100% |  |  |  |  |  |
| 318 | 3.2.2.4 | Q5 - Entrega Semanal (1) | milestone, manual | 0d | 2014-10-06 A | 2014-10-06 A | 317 | 100% |  |  |  |  |  |
| 319 | 3.2.2.5 | Q5 - Entrega Semanal Semana (2) | milestone, manual | 0d | 2014-10-13 A | 2014-10-13 A | 317 | 100% |  |  | OM |  |  |
| 320 | 3.2.2.6 | Q6 - Revisar el ajuste del proceso | manual | 1.83d | 2014-09-30 A | 2014-09-30 A |  | 100% |  |  |  |  |  |
| 321 | 3.2.2.7 | **Q7 - Evaluar la calidad de los productos** |  | 3.5d | 2014-09-29 A | 2014-09-30 A |  | 100% |  |  |  |  |  |
| 322 | 3.2.2.7.1 | Q7 - Evaluar Diseño de Arquitectura | manual | 3.5d | 2014-09-29 A | 2014-09-30 A |  | 100% |  |  |  |  |  |
| 323 | 3.2.2.8 | Q - Informe de revisión de SQA (1) | milestone, manual | 0d | 2014-10-01 A | 2014-10-01 A | 321, 320 | 100% |  |  |  |  |  |

| ID | WBS | Task | Type | Duration | Start | Finish | Predecessors | Complete | Actual finish | Resources | Work | Actual work |
| --- | --- | --- | --- | --- | --- | --- | --- | --- | --- | --- | --- | --- |
| 324 | 3.2.3 | **Gestión de Configuración** |  | 1.83d? | 2014-09-30 A | 2014-09-30 |  | 100% | 2014-10-05 |  |  |  |
| 325 | 3.2.3.1 | C3 - Seguimiento de la línea base | manual | 1.83d | 2014-09-30 A | 2014-09-30 A |  | 100% |  |  |  |  |
| 326 | 3.2.3.2 | C3 - Informe de la línea base del proyecto (1) | milestone, manual | 0d | 2014-10-05 A | 2014-10-05 A | 325 | 100% |  | DS |  |  |
| 327 | 3.2.3.3 | C5 - Control de cambios | manual | 1.83d | 2014-09-30 A | 2014-09-30 A |  | 100% |  |  |  |  |
| 328 | 3.2.3.4 | C5 - Registro de versiones (2) | milestone, manual | 0d | 2014-09-30 A | 2014-09-30 A |  | 100% |  | ET |  |  |
| 329 | 3.2.3.5 | C7 - Describir la versión | manual | 1.83d | 2014-09-30 A | 2014-09-30 A |  | 100% |  |  |  |  |
| 330 | 3.2.3.6 | C7 - Especificación de la liberación (1) | milestone, manual | 0d | 2014-10-01 A | 2014-10-01 A | 329 | 100% |  | DS; ET |  |  |
| 331 | 3.2.3.7 | C8 - Escribir las notas de la versión | manual | 1.83d | 2014-09-30 A | 2014-09-30 A |  | 100% |  |  |  |  |
| 332 | 3.2.3.8 | C8 - Descripción de la liberación (2) | milestone, manual | 0d | 2014-09-30 A | 2014-09-30 A |  | 100% |  | ET |  |  |
| 333 | 3.2.4 | **Gestión de Proyecto** |  | 1.83d? | 2014-09-30 A | 2014-09-30 |  | 100% | 2014-10-05 |  | 11h | 11h |
| 334 | 3.2.4.1 | G10 - Evaluar y ajustar el plan de proyecto | manual | 1.83d | 2014-09-30 A | 2014-09-30 A |  | 100% |  |  |  |  |
| 335 | 3.2.4.2 | G13 - Evaluar la fase | manual | 1.83d | 2014-09-30 A | 2014-09-30 A |  | 100% |  |  |  |  |
| 336 | 3.2.4.3 | G13 - Informe de conclusiond e fase (2) | milestone, manual | 0d | 2014-09-30 A | 2014-09-30 A |  | 100% |  | IA |  |  |
| 337 | 3.2.4.4 | G15 - Revisión técnica y administrativa | manual | 1.83d | 2014-09-30 A | 2014-09-30 A |  | 100% |  |  |  |  |
| 338 | 3.2.4.5 | G16 - Reunión de responsables por área | manual | 1.83d | 2014-09-30 A | 2014-09-30 A |  | 100% |  |  |  |  |
| 339 | 3.2.4.6 | G - Plan de la iteración (2) | milestone, manual | 0d | 2014-09-30 A | 2014-09-30 A |  | 100% |  | IA |  |  |
| 340 | 3.2.4.7 | G18 - Presentación al director de proyecto | manual | 1.83d | 2014-09-30 A | 2014-09-30 A |  | 100% |  |  |  |  |
| 341 | 3.2.4.8 | G2 - Seguimiento del proyecto | manual | 1.83d | 2014-09-30 A | 2014-09-30 A |  | 100% |  |  |  |  |
| 342 | 3.2.4.9 | G2 - Informe de situación del proyecto (1) | milestone, manual | 0d | 2014-10-05 A | 2014-10-05 A | 341 | 100% |  | IA |  |  |
| 343 | 3.2.4.10 | G2 - Informe de situación del proyecto (2) | milestone, manual | 0d | 2014-09-30 A | 2014-09-30 A |  | 100% |  | IA |  |  |
| 344 | 3.2.4.11 | G3 - Estimaciones y mediciones | manual | 1.83d | 2014-09-30 A | 2014-09-30 A |  | 100% |  |  |  |  |
| 345 | 3.2.4.12 | G4 - Gestión de riesgos | manual | 1.83d | 2014-09-30 A | 2014-09-30 A |  | 100% |  |  |  |  |
| 346 | 3.2.4.13 | G5 - Registrar esfuerzo | manual | 1.83d | 2014-09-30 A | 2014-09-30 A |  | 100% |  | TODOS | 11h | 11h |
| 347 | 3.2.4.14 | G5 - Registro de Actividades (1) | milestone, manual | 0d | 2014-10-05 A | 2014-10-05 A | 346 | 100% |  | IA |  |  |
| 348 | 3.2.4.15 | G6 - Reunión de equipo | manual | 1.83d | 2014-09-30 A | 2014-09-30 A |  | 100% |  |  |  |  |
| 349 | 3.2.4.16 | G7 - Elaborar acta de reunión de equipo | manual | 1.83d | 2014-09-30 A | 2014-09-30 A |  | 100% |  |  |  |  |
| 350 | 3.2.4.17 | G8 - Reunión de seguimiento | manual | 1.83d | 2014-09-30 A | 2014-09-30 A |  | 100% |  |  |  |  |
| 351 | 3.2.4.18 | G9 - Ajustar y controlar el desarrollo | manual | 1.83d | 2014-09-30 A | 2014-09-30 A |  | 100% |  |  |  |  |
| 352 | 3.2.4.19 | G9 - Plan de desarrollo (1) | milestone, manual | 0d | 2014-10-05 A | 2014-10-05 A | 351 | 100% |  | DS |  |  |
| 353 | 3.2.4.20 | G9 - Plan de desarrollo (2) | milestone, manual | 0d | 2014-09-30 A | 2014-09-30 A |  | 100% |  | DS |  |  |

| ID | WBS | Task | Type | Duration | Start | Finish | Predecessors | Complete | Actual start | Actual finish | Resources | Work | Actual work |
| --- | --- | --- | --- | --- | --- | --- | --- | --- | --- | --- | --- | --- | --- |
| 354 | 3.2.5 | **Plan de Implantación** |  | 1.83d? | 2014-09-30 A | 2014-09-30 A |  | 100% |  |  |  |  |  |
| 355 | 3.2.5.1 | P2 - Documentación de usuario | manual | 1.83d | 2014-09-30 A | 2014-09-30 A |  | 100% |  |  |  |  |  |
| 356 | 3.2.5.2 | P2 - Materiales para soporte al usuario (2) | milestone, manual | 0d | 2014-09-30 A | 2014-09-30 A |  | 100% |  |  | AE |  |  |
| 357 | 3.2.6 | **Implementación** |  | 1.83d? | 2014-09-30 | 2014-09-30 |  | 100% | 2014-08-15 | 2014-10-10 |  | 892h | 892h |
| 358 | 3.2.6.1 | I3 - Corregir la implementación | manual | 1.83d | 2014-09-30 A | 2014-09-30 A |  | 100% |  |  |  |  |  |
| 359 | 3.2.6.2 | I4 - Planificar la integración de la iteración | manual | 1.83d | 2014-09-30 A | 2014-09-30 A |  | 100% |  |  |  |  |  |
| 360 | 3.2.6.3 | I4 - Plan de iteacion de la integracion (2) | milestone, manual | 0d | 2014-09-30 A | 2014-09-30 A |  | 100% |  |  | Implementadores |  |  |
| 361 | 3.2.6.4 | I5 - Integrar el sistema | manual | 1.83d | 2014-09-30 A | 2014-09-30 A |  | 100% |  |  |  |  |  |
| 362 | 3.2.6.5 | I6 - Documentación técnica | manual | 1.83d | 2014-09-30 A | 2014-09-30 A |  | 100% |  |  |  |  |  |
| 363 | 3.2.6.6 | I7 - Verificación unitaria de módulo | manual | 1.83d | 2014-09-30 A | 2014-09-30 A |  | 100% |  |  |  |  |  |
| 364 | 3.2.6.7 | **I1 - Semana1** |  | 6d | 2014-10-01 A | 2014-10-04 | 67 | 100% |  | 2014-10-10 |  | 412h | 412h |
| 365 | 3.2.6.7.1 | I1 - CU Visualización de interpolado en el Mapa | manual | 5d | 2014-10-01 A | 2014-10-03 A |  | 100% |  |  | RL; MB | 60h | 60h |
| 366 | 3.2.6.7.2 | **I1 - CU Visualizar coloreo de motes** |  | 5d | 2014-10-01 A | 2014-10-03 |  | 100% |  | 2014-10-01 |  | 66h | 66h |
| 367 | 3.2.6.7.2.1 | I1 - CU Visualizar coloreo de motes Lógica SA | manual | 1.83d | 2014-10-01 A | 2014-10-01 A |  | 100% |  |  | SB; ET | 22h | 22h |
| 368 | 3.2.6.7.2.2 | I1 - CU Visualizar coloreo de motes Presentación | manual | 1.83d | 2014-10-01 A | 2014-10-01 A |  | 100% |  |  | MB; RL | 22h | 22h |
| 369 | 3.2.6.7.2.3 | I7 - CU Visualizar coloreo de motes Verificaciones unitarias | manual | 1.83d | 2014-10-01 A | 2014-10-01 A |  | 100% |  |  | SB; ET | 22h | 22h |
| 370 | 3.2.6.7.3 | **I1 - CU Alta Alarma** |  | 5d | 2014-10-01 A | 2014-10-03 |  | 100% |  | 2014-10-01 |  | 66h | 66h |
| 371 | 3.2.6.7.3.1 | I1 - CU Alta Alarma Lógica SA | manual | 1.83d | 2014-10-01 A | 2014-10-01 A |  | 100% |  |  | MF; SF | 22h | 22h |
| 372 | 3.2.6.7.3.2 | I1 - CU Alta Alarma Presentación | manual | 1.83d | 2014-10-01 A | 2014-10-01 A |  | 100% |  |  | JC; FG | 22h | 22h |
| 373 | 3.2.6.7.3.3 | I7 - CU Alta Alarma Verificaciones unitarias | manual | 1.83d | 2014-10-01 A | 2014-10-01 A |  | 100% |  |  | MF; SF | 22h | 22h |
| 374 | 3.2.6.7.4 | **I1 - CU Modificacion red** |  | 5d | 2014-10-01 A | 2014-10-03 |  | 100% |  | 2014-10-01 |  | 110h | 110h |
| 375 | 3.2.6.7.4.1 | I1 - CU Modificacion red Lógica SA | manual | 1.83d | 2014-10-01 A | 2014-10-01 A |  | 100% |  |  | SB; ET; SF; MF | 44h | 44h |
| 376 | 3.2.6.7.4.2 | I1 - CU Modificacion red Presentación | manual | 1.83d | 2014-10-01 A | 2014-10-01 A |  | 100% |  |  | MB; RL | 22h | 22h |
| 377 | 3.2.6.7.4.3 | I7 - CU Modificacion red Verificaciones unitarias | manual | 1.83d | 2014-10-01 A | 2014-10-01 A |  | 100% |  |  | SB; ET; SF; MF | 44h | 44h |

| ID | WBS | Task | Type | Duration | Start | Finish | Predecessors | Complete | Actual start | Actual finish | Constraint | Resources | Work | Actual work |
| --- | --- | --- | --- | --- | --- | --- | --- | --- | --- | --- | --- | --- | --- | --- |
| 378 | 3.2.6.7.5 | **I1 - CU Visualizar gráficas** |  | 5d | 2014-10-01 A | 2014-10-03 |  | 100% |  | 2014-10-01 |  |  | 66h | 66h |
| 379 | 3.2.6.7.5.1 | I1 - CU Visualizar gráficas Lógica SA | manual | 1.83d | 2014-10-01 A | 2014-10-01 A |  | 100% |  |  |  | SB; ET | 22h | 22h |
| 380 | 3.2.6.7.5.2 | I1 - CU Visualizar gráficas Presentación | manual | 1.83d | 2014-10-01 A | 2014-10-01 A |  | 100% |  |  |  | JC; FG | 22h | 22h |
| 381 | 3.2.6.7.5.3 | I7 - CU Visualizar gráficas Verificaciones unitarias | manual | 1.83d | 2014-10-01 A | 2014-10-01 A |  | 100% |  |  |  | SB; ET | 22h | 22h |
| 382 | 3.2.6.7.6 | **I1 - CU Notificar Alarma** |  | 5d | 2014-10-01 A | 2014-10-03 |  | 100% |  | 2014-10-01 |  |  | 44h | 44h |
| 383 | 3.2.6.7.6.1 | I1 - CU Notificar Alarma Lógica Daemon | manual | 1.83d | 2014-10-01 A | 2014-10-01 A |  | 100% |  |  |  | MF; SF | 22h | 22h |
| 384 | 3.2.6.7.6.2 | I7 - CU Notificar Alarma Verificaciones unitarias | manual | 1.83d | 2014-10-01 A | 2014-10-01 A |  | 100% |  |  |  | SF; MF | 22h | 22h |
| 385 | 3.2.6.7.7 | Liberación para Testing | milestone, manual | 0d | 2014-10-08 A | 2014-10-08 A |  | 100% |  |  |  | DS; FP; IA; AE; OM |  |  |
| 386 | 3.2.6.7.8 | Presentación para el Clientes | milestone, manual | 0d | 2014-10-10 A | 2014-10-10 A | 90 | 100% |  |  |  | TODOS |  |  |
| 387 | 3.2.6.8 | **I1 - Semana2** |  | 7d | 2014-10-02 | 2014-10-05 | 69 | 100% | 2014-08-15 | 2014-10-04 |  |  | 480h | 480h |
| 388 | 3.2.6.8.1 | **I1 - CU Visualizar Capas de una red** |  | 5d | 2014-10-02 | 2014-10-04 A |  | 100% | 2014-08-15 |  |  | ET; SB; RL; MB | 120h | 120h |
| 389 | 3.2.6.8.1.1 | I1 - CU Visualizar Capas de una red Lógica SA |  | 1d | 2014-08-15 A | 2014-08-15 A |  | 100% |  |  | finish no earlier than 2014-08-15 |  |  |  |
| 390 | 3.2.6.8.1.2 | I1 - CU Visualizar Capas de una red Presentación | manual | 1.83d | 2014-10-02 A | 2014-10-02 A |  | 100% |  |  |  |  |  |  |
| 391 | 3.2.6.8.1.3 | I7 - CU Visualizar Capas de una red Verificaciones unitarias | manual | 1.83d | 2014-10-02 A | 2014-10-02 A |  | 100% |  |  |  |  |  |  |
| 392 | 3.2.6.8.2 | **I1 - CU generar resumenes de información procesada** |  | 5d | 2014-10-02 A | 2014-10-04 A |  | 100% |  |  |  | SF; MF; JC; FG | 120h | 120h |
| 393 | 3.2.6.8.2.1 | I1 - CU generar resumenes de información procesada Lógica SA | manual | 1.83d | 2014-10-02 A | 2014-10-02 A |  | 100% |  |  |  |  |  |  |
| 394 | 3.2.6.8.2.2 | I1 - CU generar resumenes de información procesada Presentación | manual | 1.83d | 2014-10-02 A | 2014-10-02 A |  | 100% |  |  |  |  |  |  |
| 395 | 3.2.6.8.2.3 | I7 - CU generar resumenes de información procesada Verificaciones unitarias | manual | 1.83d | 2014-10-02 A | 2014-10-02 A |  | 100% |  |  |  |  |  |  |
| 396 | 3.2.6.8.3 | **I1 - CU Visualizar árbol** |  | 5d | 2014-10-02 A | 2014-10-04 A |  | 100% |  |  |  | SF; MF; JC; FG | 120h | 120h |
| 397 | 3.2.6.8.3.1 | I1 - CU Visualizar árbol Lógica SA | manual | 1.83d | 2014-10-02 A | 2014-10-02 A |  | 100% |  |  |  |  |  |  |
| 398 | 3.2.6.8.3.2 | I1 - CU Visualizar árbol Presentación | manual | 1.83d | 2014-10-02 A | 2014-10-02 A |  | 100% |  |  |  |  |  |  |
| 399 | 3.2.6.8.3.3 | I7 - CU Visualizar árbol Verificaciones unitarias | manual | 1.83d | 2014-10-02 A | 2014-10-02 A |  | 100% |  |  |  |  |  |  |
| 400 | 3.2.6.8.4 | **I1 - CU Cargar capas para el mapa** |  | 5d | 2014-10-02 A | 2014-10-04 A |  | 100% |  |  |  | ET; SB; RL; MB | 120h | 120h |
| 401 | 3.2.6.8.4.1 | I1 - CU Cargar capas para el mapa Lógica SA | manual | 1.83d | 2014-10-02 A | 2014-10-02 A |  | 100% |  |  |  |  |  |  |
| 402 | 3.2.6.8.4.2 | I1 - CU Cargar capas para el mapa Presentación | manual | 1.83d | 2014-10-02 A | 2014-10-02 A |  | 100% |  |  |  |  |  |  |
| 403 | 3.2.6.8.4.3 | I7 - CU Cargar capas para el mapa Verificaciones unitarias | manual | 1.83d | 2014-10-02 A | 2014-10-02 A |  | 100% |  |  |  |  |  |  |
| 404 | 3.2.7 | Informe de Integración (2) | milestone, manual | 0d | 2014-09-30 A | 2014-09-30 A |  | 100% |  |  |  | Resp Integración |  |  |
| 405 | 3.2.8 | Liberación para Testing | manual | 1.83d | 2014-09-30 A | 2014-09-30 A |  | 100% |  |  |  |  |  |  |
| 406 | 3.2.9 | Ejecutable de la iteración (2) | milestone, manual | 0d | 2014-09-30 A | 2014-09-30 A |  | 100% |  |  |  | Implementadores |  |  |
| 407 | 3.2.10 | Presentación para el Clientes |  | 1.83d | 2014-09-30 A | 2014-09-30 A |  | 100% |  |  |  |  |  |  |

| ID | WBS | Task | Type | Duration | Start | Finish | Predecessors | Complete | Remaining | Actual finish | Resources | Work | Actual work |
| --- | --- | --- | --- | --- | --- | --- | --- | --- | --- | --- | --- | --- | --- |
| 408 | 3.2.11 | **Requerimientos** |  | 1.83d? | 2014-09-30 A | 2014-09-30 A |  | 100% |  |  |  | 11h | 11h |
| 409 | 3.2.11.1 | R2 - Especificar requerimiento | manual | 1.83d | 2014-09-30 A | 2014-09-30 A |  | 100% |  |  |  |  |  |
| 410 | 3.2.11.2 | R3 - Modelo de CU (2) | milestone, manual | 0d | 2014-09-30 A | 2014-09-30 A |  | 100% |  |  | Analistas |  |  |
| 411 | 3.2.11.3 | R5 - Validación con el cliente (2) | manual | 1.83d | 2014-09-30 A | 2014-09-30 A |  | 100% |  |  | DS | 11h | 11h |
| 412 | 3.2.12 | **Verificación** |  | 1.83d? | 2014-09-30 A | 2014-09-30 |  | 100% |  | 2014-10-05 |  | 11h | 11h |
| 413 | 3.2.12.1 | V2 - Evaluar y ajustar el plan de VyV | manual | 1.83d | 2014-09-30 A | 2014-09-30 A |  | 100% |  |  |  |  |  |
| 414 | 3.2.12.2 | V3 - Planificar las pruebas de la iteración | manual | 1.83d | 2014-09-30 A | 2014-09-30 A |  | 100% |  |  |  |  |  |
| 415 | 3.2.12.3 | V3 - Plan de verificación de la iteración (2) | milestone, manual | 0d | 2014-09-30 A | 2014-09-30 A |  | 100% |  |  | FP |  |  |
| 416 | 3.2.12.4 | V4 - Especificar los casos de prueba | manual | 1.83d | 2014-09-30 A | 2014-09-30 A |  | 100% |  |  |  |  |  |
| 417 | 3.2.12.5 | V4 - Modelo de casos de prueba (2) | manual | 1.83d | 2014-09-30 A | 2014-09-30 A |  | 100% |  |  | FP | 11h | 11h |
| 418 | 3.2.12.6 | V5 - Verificar documento | manual | 1.83d | 2014-09-30 A | 2014-09-30 A |  | 100% |  |  |  |  |  |
| 419 | 3.2.12.7 | V5 - Informe de Verificación de documento (1) | milestone, manual | 0d | 2014-10-05 A | 2014-10-05 A | 418 | 100% |  |  | FP |  |  |
| 420 | 3.2.12.8 | V6 - Generar entorno de prueba | manual | 1.83d | 2014-09-30 A | 2014-09-30 A |  | 100% |  |  |  |  |  |
| 421 | 3.2.12.9 | V7 - Ejecutar las pruebas | manual | 1.83d | 2014-09-30 A | 2014-09-30 A |  | 100% |  |  |  |  |  |
| 422 | 3.2.12.10 | V - Reporte de pruebas (1) | milestone, manual | 0d | 2014-10-01 A | 2014-10-01 A | 421, 425 | 100% |  |  | FP; DS; OM; IA |  |  |
| 423 | 3.2.12.11 | V9 - Evaluar la verificación | manual | 1.83d | 2014-09-30 A | 2014-09-30 A |  | 100% |  |  |  |  |  |
| 424 | 3.2.12.12 | V9 - Evaluación de verificación (1) | milestone, manual | 0d | 2014-10-05 A | 2014-10-05 A | 423 | 100% |  |  | FP |  |  |
| 425 | 3.2.12.13 | V11 - Ejecutar pruebas no funcionales | manual | 1.83d | 2014-09-30 A | 2014-09-30 A |  | 100% |  |  |  |  |  |
| 426 | 3.2.13 | **Comunicación** |  | 1.83d? | 2014-09-30 A | 2014-09-30 A |  | 100% |  |  |  | 11h | 11h |
| 427 | 3.2.13.1 | CM4: Gestión de "Lecciones Aprendidas" (2) | manual | 1.83d | 2014-09-30 A | 2014-09-30 A |  | 100% |  |  | IA | 11h | 11h |
| 428 | 4 | Fin de Fase Elaboración | milestone, manual | 0d | 2014-09-29 | 2014-09-29 |  |  |  |  |  |  |  |
| 429 | 5 | **Fase Construcción** |  | 51.17d | 2014-10-14 A | 2014-11-10 |  | 61% | 19.95d |  |  | 22h |  |
| 430 | 5.1 | **Iteración 1** |  | 25.5d | 2014-10-14 A | 2014-10-27 |  | 100% |  | 2014-10-14 |  |  |  |
| 431 | 5.1.1 | **Diseño** |  | 1.83d? | 2014-10-14 A | 2014-10-14 A |  | 100% |  |  |  |  |  |
| 432 | 5.1.1.1 | **D1 - Diseñar casos de uso** |  | 1.83d? | 2014-10-14 A | 2014-10-14 A |  | 100% |  |  |  |  |  |
| 433 | 5.1.1.1.1 | D1 - Corregir diseños | manual | 1.83d | 2014-10-14 A | 2014-10-14 A |  | 100% |  |  |  |  |  |
| 434 | 5.1.1.2 | D1 - Modelo de Diseño | manual | 1.83d | 2014-10-14 A | 2014-10-14 A |  | 100% |  |  |  |  |  |
| 435 | 5.1.1.3 | D1 - Modelo de Diseño (2) | manual | 1.83d | 2014-10-14 A | 2014-10-14 A |  | 100% |  |  |  |  |  |
| 436 | 5.1.1.4 | D2 - Describir la arquitectura (Corregir) | manual | 1.83d | 2014-10-14 A | 2014-10-14 A |  | 100% |  |  |  |  |  |
| 437 | 5.1.1.5 | D2 - Descripcion de la arquitectura (2) | manual | 1.83d | 2014-10-14 A | 2014-10-14 A |  | 100% |  |  |  |  |  |
| 438 | 5.1.1.6 | D3 - Comunicar el diseño a los implementadores | manual | 1.83d | 2014-10-14 A | 2014-10-14 A |  | 100% |  |  |  |  |  |
| 439 | 5.1.1.7 | D4 - Diseñar base de datos | manual | 1.83d | 2014-10-14 A | 2014-10-14 A |  | 100% |  |  |  |  |  |
| 440 | 5.1.1.8 | D4 - Modelo de datos (2) | manual | 1.83d | 2014-10-14 A | 2014-10-14 A |  | 100% |  |  |  |  |  |

| ID | WBS | Task | Type | Duration | Start | Finish | Complete |
| --- | --- | --- | --- | --- | --- | --- | --- |
| 441 | 5.1.2 | **Gestión de Calidad** |  | 1.83d? | 2014-10-14 A | 2014-10-14 A | 100% |
| 442 | 5.1.2.1 | Q3 - Evaluar y ajustar el plan de SQ | manual | 1.83d | 2014-10-14 A | 2014-10-14 A | 100% |
| 443 | 5.1.2.2 | Q4 - Revisión técnica formal | manual | 1.83d | 2014-10-14 A | 2014-10-14 A | 100% |
| 444 | 5.1.2.3 | Q5 - Revisar las entrega | manual | 1.83d | 2014-10-14 A | 2014-10-14 A | 100% |
| 445 | 5.1.2.4 | Q5 - Entrega Semanal (1) | manual | 1.83d | 2014-10-14 A | 2014-10-14 A | 100% |
| 446 | 5.1.2.5 | Q5 - Entrega Semanal Semana (2) | manual | 1.83d | 2014-10-14 A | 2014-10-14 A | 100% |
| 447 | 5.1.2.6 | Q6 - Revisar el ajuste del proceso | manual | 1.83d | 2014-10-14 A | 2014-10-14 A | 100% |
| 448 | 5.1.3 | **Gestión de Configuración** |  | 1.83d? | 2014-10-14 A | 2014-10-14 A | 100% |
| 449 | 5.1.3.1 | C3 - Seguimiento de la línea base | manual | 1.83d | 2014-10-14 A | 2014-10-14 A | 100% |
| 450 | 5.1.3.2 | C3 - Informe de la línea base del proyecto (1) | manual | 1.83d | 2014-10-14 A | 2014-10-14 A | 100% |
| 451 | 5.1.3.3 | C5 - Control de cambios | manual | 1.83d | 2014-10-14 A | 2014-10-14 A | 100% |
| 452 | 5.1.3.4 | C5 - Registro de versiones (2) | manual | 1.83d | 2014-10-14 A | 2014-10-14 A | 100% |
| 453 | 5.1.3.5 | C7 - Describir la versión | manual | 1.83d | 2014-10-14 A | 2014-10-14 A | 100% |
| 454 | 5.1.3.6 | C7 - Especificación de la liberación (1) | manual | 1.83d | 2014-10-14 A | 2014-10-14 A | 100% |
| 455 | 5.1.3.7 | C8 - Escribir las notas de la versión | manual | 1.83d | 2014-10-14 A | 2014-10-14 A | 100% |
| 456 | 5.1.3.8 | C8 - Descripción de la liberación (2) | manual | 1.83d | 2014-10-14 A | 2014-10-14 A | 100% |
| 457 | 5.1.4 | **Gestión de Proyecto** |  | 1.83d? | 2014-10-14 A | 2014-10-14 A | 100% |
| 458 | 5.1.4.1 | G10 - Evaluar y ajustar el plan de proyecto | manual | 1.83d | 2014-10-14 A | 2014-10-14 A | 100% |
| 459 | 5.1.4.2 | G13 - Evaluar la fase | manual | 1.83d | 2014-10-14 A | 2014-10-14 A | 100% |
| 460 | 5.1.4.3 | G13 - Informe de conclusiond e fase (2) | manual | 1.83d | 2014-10-14 A | 2014-10-14 A | 100% |
| 461 | 5.1.4.4 | G15 - Revisión técnica y administrativa | manual | 1.83d | 2014-10-14 A | 2014-10-14 A | 100% |
| 462 | 5.1.4.5 | G16 - Reunión de responsables por área | manual | 1.83d | 2014-10-14 A | 2014-10-14 A | 100% |
| 463 | 5.1.4.6 | G - Plan de la iteración (2) | manual | 1.83d | 2014-10-14 A | 2014-10-14 A | 100% |
| 464 | 5.1.4.7 | G18 - Presentación al director de proyecto | manual | 1.83d | 2014-10-14 A | 2014-10-14 A | 100% |
| 465 | 5.1.4.8 | G2 - Seguimiento del proyecto | manual | 1.83d | 2014-10-14 A | 2014-10-14 A | 100% |
| 466 | 5.1.4.9 | G2 - Informe de situación del proyecto (1) | manual | 1.83d | 2014-10-14 A | 2014-10-14 A | 100% |
| 467 | 5.1.4.10 | G2 - Informe de situación del proyecto (2) | manual | 1.83d | 2014-10-14 A | 2014-10-14 A | 100% |
| 468 | 5.1.4.11 | G3 - Estimaciones y mediciones | manual | 1.83d | 2014-10-14 A | 2014-10-14 A | 100% |
| 469 | 5.1.4.12 | G4 - Gestión de riesgos | manual | 1.83d | 2014-10-14 A | 2014-10-14 A | 100% |
| 470 | 5.1.4.13 | G5 - Registrar esfuerzo | manual | 1.83d | 2014-10-14 A | 2014-10-14 A | 100% |
| 471 | 5.1.4.14 | G5 - Registro de Actividades (1) | manual | 1.83d | 2014-10-14 A | 2014-10-14 A | 100% |
| 472 | 5.1.4.15 | G6 - Reunión de equipo | manual | 1.83d | 2014-10-14 A | 2014-10-14 A | 100% |
| 473 | 5.1.4.16 | G7 - Elaborar acta de reunión de equipo | manual | 1.83d | 2014-10-14 A | 2014-10-14 A | 100% |
| 474 | 5.1.4.17 | G8 - Reunión de seguimiento | manual | 1.83d | 2014-10-14 A | 2014-10-14 A | 100% |
| 475 | 5.1.4.18 | G9 - Ajustar y controlar el desarrollo | manual | 1.83d | 2014-10-14 A | 2014-10-14 A | 100% |
| 476 | 5.1.4.19 | G9 - Plan de desarrollo (1) | manual | 1.83d | 2014-10-14 A | 2014-10-14 A | 100% |
| 477 | 5.1.4.20 | G9 - Plan de desarrollo (2) | manual | 1.83d | 2014-10-14 A | 2014-10-14 A | 100% |

| ID | WBS | Task | Type | Duration | Start | Finish | Complete |
| --- | --- | --- | --- | --- | --- | --- | --- |
| 478 | 5.1.5 | **Plan de Implantación** |  | 1.83d? | 2014-10-14 A | 2014-10-14 A | 100% |
| 479 | 5.1.5.1 | P1 - Planificar la implantación | manual | 1.83d | 2014-10-14 A | 2014-10-14 A | 100% |
| 480 | 5.1.5.2 | P10 - Desarrollar los materiales para capacitación | manual | 1.83d | 2014-10-14 A | 2014-10-14 A | 100% |
| 481 | 5.1.5.3 | P2 - Documentación de usuario | manual | 1.83d | 2014-10-14 A | 2014-10-14 A | 100% |
| 482 | 5.1.5.4 | P7 - Verificar la versión del producto a liberar | manual | 1.83d | 2014-10-14 A | 2014-10-14 A | 100% |
| 483 | 5.1.6 | **Implementación** |  | 1.83d? | 2014-10-14 A | 2014-10-14 A | 100% |
| 484 | 5.1.6.1 | I3 - Corregir la implementación | manual | 1.83d | 2014-10-14 A | 2014-10-14 A | 100% |
| 485 | 5.1.6.2 | I4 - Planificar la integración de la iteración | manual | 1.83d | 2014-10-14 A | 2014-10-14 A | 100% |
| 486 | 5.1.6.3 | I5 - Integrar el sistema | manual | 1.83d | 2014-10-14 A | 2014-10-14 A | 100% |
| 487 | 5.1.6.4 | I6 - Documentación técnica | manual | 1.83d | 2014-10-14 A | 2014-10-14 A | 100% |
| 488 | 5.1.6.5 | I7 - Verificación unitaria de módulo | manual | 1.83d | 2014-10-14 A | 2014-10-14 A | 100% |
| 489 | 5.1.7 | **Requerimientos** |  | 1.83d? | 2014-10-14 A | 2014-10-14 A | 100% |
| 490 | 5.1.7.1 | R2 - Especificar requerimiento | manual | 1.83d | 2014-10-14 A | 2014-10-14 A | 100% |
| 491 | 5.1.7.2 | R5 - Validación con el cliente | manual | 1.83d | 2014-10-14 A | 2014-10-14 A | 100% |
| 492 | 5.1.8 | **Verificación** |  | 1.83d? | 2014-10-14 A | 2014-10-14 A | 100% |
| 493 | 5.1.8.1 | V2 - Evaluar y ajustar el plan de VyV | manual | 1.83d | 2014-10-14 A | 2014-10-14 A | 100% |
| 494 | 5.1.8.2 | V3 - Planificar las pruebas de la iteración | manual | 1.83d | 2014-10-14 A | 2014-10-14 A | 100% |
| 495 | 5.1.8.3 | V3 - Plan de verificación de la iteración (2) | manual | 1.83d | 2014-10-14 A | 2014-10-14 A | 100% |
| 496 | 5.1.8.4 | V4 - Especificar los casos de prueba | manual | 1.83d | 2014-10-14 A | 2014-10-14 A | 100% |
| 497 | 5.1.8.5 | V4 - Modelo de casos de prueba (2) | manual | 1.83d | 2014-10-14 A | 2014-10-14 A | 100% |
| 498 | 5.1.8.6 | V5 - Verificar documento | manual | 1.83d | 2014-10-14 A | 2014-10-14 A | 100% |
| 499 | 5.1.8.7 | V5 - Informe de Verificación de documento (1) | manual | 1.83d | 2014-10-14 A | 2014-10-14 A | 100% |
| 500 | 5.1.8.8 | V6 - Generar entorno de prueba | manual | 1.83d | 2014-10-14 A | 2014-10-14 A | 100% |
| 501 | 5.1.8.9 | V7 - Ejecutar las pruebas | manual | 1.83d | 2014-10-14 A | 2014-10-14 A | 100% |
| 502 | 5.1.8.10 | V - Reporte de pruebas (1) | manual | 1.83d | 2014-10-14 A | 2014-10-14 A | 100% |
| 503 | 5.1.8.11 | V9 - Evaluar la verificación | manual | 1.83d | 2014-10-14 A | 2014-10-14 A | 100% |
| 504 | 5.1.8.12 | V9 - Evaluación de verificación (1) | manual | 1.83d | 2014-10-14 A | 2014-10-14 A | 100% |
| 505 | 5.1.8.13 | V11 - Ejecutar pruebas no funcionales | manual | 1.83d | 2014-10-14 A | 2014-10-14 A | 100% |

| ID | WBS | Task | Type | Duration | Start | Finish | Complete | Resources | Work |
| --- | --- | --- | --- | --- | --- | --- | --- | --- | --- |
| 506 | 5.1.9 | **Comunicación** |  | 1.83d? | 2014-10-14 A | 2014-10-14 A | 100% |  |  |
| 507 | 5.1.9.1 | CM4 - Gestión de "Lecciones Aprendidas" | manual | 1.83d | 2014-10-14 A | 2014-10-14 A | 100% |  |  |
| 508 | 5.2 | **Iteración 2** |  | 25.5d | 2014-10-28 | 2014-11-10 |  |  | 22h |
| 509 | 5.2.1 | **Gestión de Calidad** |  | 1.83d? | 2014-10-28 | 2014-10-28 |  |  |  |
| 510 | 5.2.1.1 | Q3 - Evaluar y ajustar el plan de SQA (1) | manual | 1.83d? | 2014-10-28 | 2014-10-28 |  |  |  |
| 511 | 5.2.1.2 | Q4 - Revisión técnica formal | manual | 1.83d? | 2014-10-28 | 2014-10-28 |  |  |  |
| 512 | 5.2.1.3 | Q4 - Informe de RTF (1) ?? | milestone, manual | 0d | 2014-10-28 | 2014-10-28 |  |  |  |
| 513 | 5.2.1.4 | Q5 - Revisar las entrega | manual | 1.83d? | 2014-10-28 | 2014-10-28 |  |  |  |
| 514 | 5.2.1.5 | Q5 - Entrega Semanal SQA (1) | milestone, manual | 0d | 2014-10-28 | 2014-10-28 |  |  |  |
| 515 | 5.2.1.6 | Q5 - Entrega Semanal SQA (2) | milestone, manual | 0d | 2014-10-28 | 2014-10-28 |  |  |  |
| 516 | 5.2.1.7 | Q6 - Revisar el ajuste del proceso | manual | 1.83d? | 2014-10-28 | 2014-10-28 |  |  |  |
| 517 | 5.2.1.8 | Q6 - Informe de revisión (1) ?? | milestone, manual | 0d | 2014-10-28 | 2014-10-28 |  |  |  |
| 518 | 5.2.1.9 | Q7 - Evaluar la calidad de los productos | manual | 1.83d? | 2014-10-28 | 2014-10-28 |  |  |  |
| 519 | 5.2.2 | **Gestión de Configuración** |  | 1.83d? | 2014-10-28 | 2014-10-28 |  |  |  |
| 520 | 5.2.2.1 | C3 - Seguimiento de la línea base | manual | 1.83d? | 2014-10-28 | 2014-10-28 |  |  |  |
| 521 | 5.2.2.2 | C3 - Informe de la línea base del proyecto (1) | milestone, manual | 0d | 2014-10-28 | 2014-10-28 |  |  |  |
| 522 | 5.2.2.3 | C5 - Control de cambio | manual | 1.83d? | 2014-10-28 | 2014-10-28 |  |  |  |
| 523 | 5.2.2.4 | C5 - Gestión de cambios (2) | milestone, manual | 0d | 2014-10-28 | 2014-10-28 |  | ET |  |
| 524 | 5.2.2.5 | C5 - Registro de versiones (2) | milestone, manual | 0d | 2014-10-28 | 2014-10-28 |  |  |  |
| 525 | 5.2.2.6 | C7 - Describir la versión | manual | 1.83d? | 2014-10-28 | 2014-10-28 |  |  |  |
| 526 | 5.2.2.7 | C7 - Especificación de la liberación (1) | milestone, manual | 0d | 2014-10-28 | 2014-10-28 |  |  |  |
| 527 | 5.2.2.8 | C7 - Especificación de la liberación (2) | milestone, manual | 0d | 2014-10-28 | 2014-10-28 |  |  |  |
| 528 | 5.2.2.9 | C8 - Escribir las notas de la versión | manual | 1.83d? | 2014-10-28 | 2014-10-28 |  |  |  |
| 529 | 5.2.2.10 | C8 - Descripción de la liberación (2) | milestone, manual | 0d | 2014-10-28 | 2014-10-28 |  | DS; ET |  |

| ID | WBS | Task | Type | Duration | Start | Finish |
| --- | --- | --- | --- | --- | --- | --- |
| 530 | 5.2.3 | **Gestión de Proyecto** |  | 1.83d? | 2014-10-28 | 2014-10-28 |
| 531 | 5.2.3.1 | G10 - Evaluar y ajustar el plan de proyecto | manual | 1.83d? | 2014-10-28 | 2014-10-28 |
| 532 | 5.2.3.2 | G10 - Documento de Evaluación y ajustes al Plan de Proyecto (1) | milestone, manual | 0d | 2014-10-28 | 2014-10-28 |
| 533 | 5.2.3.3 | G13 - Evaluar la fase | manual | 1.83d? | 2014-10-28 | 2014-10-28 |
| 534 | 5.2.3.4 | G13 - Informe de conclusiones de fase (2) | milestone, manual | 0d | 2014-10-28 | 2014-10-28 |
| 535 | 5.2.3.5 | G15 - Revisión técnica y administrativa | manual | 1.83d? | 2014-10-28 | 2014-10-28 |
| 536 | 5.2.3.6 | G16 - Reunión de responsables por área | manual | 1.83d? | 2014-10-28 | 2014-10-28 |
| 537 | 5.2.3.7 | G18 - Presentación al director de proyecto | manual | 1.83d? | 2014-10-28 | 2014-10-28 |
| 538 | 5.2.3.8 | G2 - Seguimiento del proyecto | manual | 1.83d? | 2014-10-28 | 2014-10-28 |
| 539 | 5.2.3.9 | G2 - Informe de situación del proyecto (1) | milestone, manual | 0d | 2014-10-28 | 2014-10-28 |
| 540 | 5.2.3.10 | G2 - Informe de situación del proyecto (2) | milestone, manual | 0d | 2014-10-28 | 2014-10-28 |
| 541 | 5.2.3.11 | G4 - Gestión de riesgo | manual | 1.83d? | 2014-10-28 | 2014-10-28 |
| 542 | 5.2.3.12 | G5 - Registrar esfuerzo | manual | 1.83d? | 2014-10-28 | 2014-10-28 |
| 543 | 5.2.3.13 | G5 - Registro de actividades (1) | milestone, manual | 0d | 2014-10-28 | 2014-10-28 |
| 544 | 5.2.3.14 | G5 - Registro de actividades (2) | milestone, manual | 0d | 2014-10-28 | 2014-10-28 |
| 545 | 5.2.3.15 | G6 - Reunión de equipo (1) | manual | 1.67d | 2014-10-31 | 2014-10-31 |
| 546 | 5.2.3.16 | G6 - Reunión de equipo (2) | manual | 1.67d | 2014-11-07 | 2014-11-07 |
| 547 | 5.2.3.17 | G7 - Acta de reunión de equipo (1) | milestone, manual | 0d | 2014-10-28 | 2014-10-28 |
| 548 | 5.2.3.18 | G7 - Acta de reunión de equipo (2) | milestone, manual | 0d | 2014-10-28 | 2014-10-28 |
| 549 | 5.2.3.19 | G8 - Reunión de seguimiento | manual | 1.83d? | 2014-10-28 | 2014-10-28 |
| 550 | 5.2.3.20 | G9 - Ajustar y controlar el desarrollo | manual | 1.83d? | 2014-10-28 | 2014-10-28 |
| 551 | 5.2.3.21 | G9 - Plan de desarrollo (1) | milestone, manual | 0d | 2014-10-28 | 2014-10-28 |
| 552 | 5.2.3.22 | G9 - Plan de desarrollo (2) | milestone, manual | 0d | 2014-10-28 | 2014-10-28 |
| 553 | 5.2.3.23 | G - Plan de la iteración (2) | milestone, manual | 0d | 2014-10-28 | 2014-10-28 |

| ID | WBS | Task | Type | Duration | Start | Finish |
| --- | --- | --- | --- | --- | --- | --- |
| 554 | 5.2.4 | **Plan de Implantación** |  | 1.83d? | 2014-10-28 | 2014-10-28 |
| 555 | 5.2.4.1 | P1 - Planificar la implantación | manual | 1.83d? | 2014-10-28 | 2014-10-28 |
| 556 | 5.2.4.2 | P1 - Plan de implantación (1) | milestone, manual | 0d | 2014-10-28 | 2014-10-28 |
| 557 | 5.2.4.3 | P1 - Plan de implantación (2) | milestone, manual | 0d | 2014-10-28 | 2014-10-28 |
| 558 | 5.2.4.4 | P10 - Desarrollar los materiales para capacitación | manual | 1.83d? | 2014-10-28 | 2014-10-28 |
| 559 | 5.2.4.5 | P10 - Materiales para capacitación (1) | milestone, manual | 0d | 2014-10-28 | 2014-10-28 |
| 560 | 5.2.4.6 | P10 - Materiales para capacitación (2) | milestone, manual | 0d | 2014-10-28 | 2014-10-28 |
| 561 | 5.2.4.7 | P2 - Documentación de usuario | manual | 1.83d? | 2014-10-28 | 2014-10-28 |
| 562 | 5.2.4.8 | P2 - Materiales para soporte de usuario (1) | milestone, manual | 0d | 2014-10-28 | 2014-10-28 |
| 563 | 5.2.4.9 | P2 - Materiales para soporte de usuario (2) | milestone, manual | 0d | 2014-10-28 | 2014-10-28 |
| 564 | 5.2.4.10 | P3 - Elaborar la preseentación del sistema para el cliente | manual | 1.83d? | 2014-10-28 | 2014-10-28 |
| 565 | 5.2.4.11 | P3 - Presentación del sistema (2) | milestone, manual | 0d | 2014-10-28 | 2014-10-28 |
| 566 | 5.2.4.12 | P7 - Verificar la versión del producto a liberar | manual | 1.83d? | 2014-10-28 | 2014-10-28 |
| 567 | 5.2.4.13 | P8 - Pruebas beta del producto | manual | 1.83d? | 2014-10-28 | 2014-10-28 |
| 568 | 5.2.4.14 | P4 - Producir la versión Beta del producto | manual | 1.83d? | 2014-10-28 | 2014-10-28 |
| 569 | 5.2.4.15 | P4 - Versión beta del producto (2) | milestone, manual | 0d | 2014-10-28 | 2014-10-28 |
| 570 | 5.2.5 | **Implementación** |  | 1.83d? | 2014-10-28 | 2014-10-28 |
| 571 | 5.2.5.1 | I3 - Corregir la implementación | manual | 1.83d? | 2014-10-28 | 2014-10-28 |
| 572 | 5.2.5.2 | I5 - Integrar el sistema | manual | 1.83d? | 2014-10-28 | 2014-10-28 |
| 573 | 5.2.5.3 | I5 - Informe de integración (2) | milestone, manual | 0d | 2014-10-28 | 2014-10-28 |
| 574 | 5.2.5.4 | I6 - Documentación técnica (1) | manual | 1.83d? | 2014-10-28 | 2014-10-28 |
| 575 | 5.2.5.5 | I6 - Documentación técnica (2) | manual | 1.83d? | 2014-10-28 | 2014-10-28 |
| 576 | 5.2.5.6 | I7 - Verificación unitaria de módulo | manual | 1.83d? | 2014-10-28 | 2014-10-28 |
| 577 | 5.2.5.7 | I7 - Informe de verificación unitaria (1) | milestone, manual | 0d | 2014-10-28 | 2014-10-28 |
| 578 | 5.2.5.8 | Ejecutable de la Interación (1) | milestone, manual | 0d | 2014-10-28 | 2014-10-28 |

| ID | WBS | Task | Type | Duration | Start | Finish | Total slack | Constraint | Resources | Work |
| --- | --- | --- | --- | --- | --- | --- | --- | --- | --- | --- |
| 579 | 5.2.6 | **Verificación** |  | 1.83d? | 2014-10-28 | 2014-10-28 |  |  |  | 22h |
| 580 | 5.2.6.1 | V2 - Evaluar y ajustar el plan de VyV (1) | manual | 1.83d? | 2014-10-28 | 2014-10-28 |  |  |  |  |
| 581 | 5.2.6.2 | V3 - Planificar las pruebas de la iteración | manual | 1.83d? | 2014-10-28 | 2014-10-28 |  |  |  |  |
| 582 | 5.2.6.3 | V3 - Plan de verificación de la iteración (2) | milestone, manual | 0d | 2014-10-28 | 2014-10-28 |  |  |  |  |
| 583 | 5.2.6.4 | V4 - Especificar los casos de prueba | manual | 1.83d? | 2014-10-28 | 2014-10-28 |  |  |  |  |
| 584 | 5.2.6.5 | V4 - Modelo de casos de prueba (2) | milestone, manual | 0d | 2014-10-28 | 2014-10-28 |  |  | FP |  |
| 585 | 5.2.6.6 | V5 - Verificar documento | manual | 1.83d? | 2014-10-28 | 2014-10-28 |  |  |  |  |
| 586 | 5.2.6.7 | V5 - Informe de verificación de documento (Documentación técnica) (1) | milestone, manual | 0d | 2014-10-28 | 2014-10-28 |  |  |  |  |
| 587 | 5.2.6.8 | V6 - Generar entorno de prueba | manual | 1.83d? | 2014-10-28 | 2014-10-28 |  |  |  |  |
| 588 | 5.2.6.9 | V7 - Ejecutar las prueba | manual | 1.83d? | 2014-10-28 | 2014-10-28 |  |  |  |  |
| 589 | 5.2.6.10 | V7 - Reporte de pruebas (1) | milestone, manual | 0d | 2014-10-28 | 2014-10-28 |  |  | Verificadores |  |
| 590 | 5.2.6.11 | V7 - Reporte de pruebas (2) | milestone, manual | 0d | 2014-10-28 | 2014-10-28 |  |  |  |  |
| 591 | 5.2.6.12 | V9 - Evaluar la verificación (1) | manual | 1.83d? | 2014-10-28 | 2014-10-28 |  |  | FP | 11h |
| 592 | 5.2.6.13 | V9 - Evaluar la verificación (2) | manual | 1.83d? | 2014-10-28 | 2014-10-28 |  |  | FP | 11h |
| 593 | 5.2.6.14 | V - Revisión por pares (1) | manual | 1.83d? | 2014-10-28 | 2014-10-28 |  |  |  |  |
| 594 | 5.2.7 | **Comunicación** |  | 1.83d? | 2014-10-28 | 2014-10-28 |  |  |  |  |
| 595 | 5.2.7.1 | CM4 - Gestión de "Lecciones Aprendidas" (2) | manual | 1.83d? | 2014-10-28 | 2014-10-28 |  |  |  |  |
| 596 | 6 | Fin de Fase | milestone | 0d | 2014-11-10 | 2014-11-10 | 27.33d | start no earlier than 2014-11-10 |  |  |
| 597 | 7 | **Fase Transición** |  | 25.5d | 2014-11-11 | 2014-11-24 |  |  |  |  |
| 598 | 7.1 | **Iteración 1** |  | 25.5d | 2014-11-11 | 2014-11-24 |  |  |  |  |
| 599 | 7.1.1 | **Satisfacción del Cliente** |  | 12.67d | 2014-11-11 | 2014-11-17 |  |  |  |  |
| 600 | 7.1.1.1 | CU2 - Seguimiento de satisfacción del cliente | manual | 1.83d | 2014-11-11 | 2014-11-11 |  |  |  |  |
| 601 | 7.1.2 | **Gestión de Calidad** |  | 12.67d | 2014-11-18 | 2014-11-24 |  |  |  |  |
| 602 | 7.1.2.1 | Q5 - Revisar las entregas | manual | 1.83d | 2014-11-18 | 2014-11-18 |  |  |  |  |
| 603 | 7.1.2.2 | Q7 - Evaluar la calidad de los productos | manual | 1.83d | 2014-11-18 | 2014-11-18 |  |  |  |  |
| 604 | 7.1.2.3 | Q8 - Realizar el informe final de SQA | manual | 1.83d | 2014-11-18 | 2014-11-18 |  |  |  |  |

| ID | WBS | Task | Type | Duration | Start | Finish | Total slack |
| --- | --- | --- | --- | --- | --- | --- | --- |
| 605 | 7.1.3 | **Gestión de Configuración** |  | 1.83d | 2014-11-11 | 2014-11-11 | 0d |
| 606 | 7.1.3.1 | C3 - Seguimiento de la línea base | manual | 1.83d | 2014-11-11 | 2014-11-11 |  |
| 607 | 7.1.3.2 | C6 - Realizar el informe final de SCM | manual | 1.83d | 2014-11-11 | 2014-11-11 |  |
| 608 | 7.1.3.3 | C7 - Describir la versión | manual | 1.83d | 2014-11-11 | 2014-11-11 |  |
| 609 | 7.1.3.4 | C8 - Escribir las notas de la versión | manual | 1.83d | 2014-11-11 | 2014-11-11 |  |
| 610 | 7.1.4 | **Gestión de Proyecto** |  | 1.83d | 2014-11-11 | 2014-11-11 | 0d |
| 611 | 7.1.4.1 | G11 - Realizar el informe final del proyecto | manual | 1.83d | 2014-11-11 | 2014-11-11 |  |
| 612 | 7.1.4.2 | G12 - Preparar el cierre del proyecto | manual | 1.83d | 2014-11-11 | 2014-11-11 |  |
| 613 | 7.1.4.3 | G13 - Evaluar la fase | manual | 1.83d | 2014-11-11 | 2014-11-11 |  |
| 614 | 7.1.4.4 | G14 - Reunión evaluativa con el director del proyecto | manual | 1.83d | 2014-11-11 | 2014-11-11 |  |
| 615 | 7.1.4.5 | G15 - Revisión técnica y administrativa | manual | 1.83d | 2014-11-11 | 2014-11-11 |  |
| 616 | 7.1.4.6 | G18 - Presentación al director de proyecto | manual | 1.83d | 2014-11-11 | 2014-11-11 |  |
| 617 | 7.1.4.7 | G2 - Seguimiento del proyecto | manual | 1.83d | 2014-11-11 | 2014-11-11 |  |
| 618 | 7.1.4.8 | G5 - Registrar esfuerzo | manual | 1.83d | 2014-11-11 | 2014-11-11 |  |
| 619 | 7.1.4.9 | G6 - Reunión de equipo | manual | 1.83d | 2014-11-11 | 2014-11-11 |  |
| 620 | 7.1.4.10 | G7 - Elaborar acta de reunión de equipo | manual | 1.83d | 2014-11-11 | 2014-11-11 |  |
| 621 | 7.1.4.11 | G8 - Reunión de seguimiento | manual | 1.83d | 2014-11-11 | 2014-11-11 |  |
| 622 | 7.1.5 | **Plan de Implantación** |  | 1.83d | 2014-11-11 | 2014-11-11 | 0d |
| 623 | 7.1.5.1 | P10 - Desarrollar los materiales para capacitación | manual | 1.83d | 2014-11-11 | 2014-11-11 |  |
| 624 | 7.1.5.2 | P11 - Preparar el entorno de capacitación | manual | 1.83d | 2014-11-11 | 2014-11-11 |  |
| 625 | 7.1.5.3 | P12 - Capacitación | manual | 1.83d | 2014-11-11 | 2014-11-11 |  |
| 626 | 7.1.5.4 | P2 - Documentación de usuario | manual | 1.83d | 2014-11-11 | 2014-11-11 |  |
| 627 | 7.1.5.5 | P4 - Producir la versión del producto a liberar | manual | 1.83d | 2014-11-11 | 2014-11-11 |  |
| 628 | 7.1.5.6 | P5 - Puesta en producción | manual | 1.83d | 2014-11-11 | 2014-11-11 |  |
| 629 | 7.1.5.7 | P6 - Realizar las pruebas de aceptación | manual | 1.83d | 2014-11-11 | 2014-11-11 |  |
| 630 | 7.1.5.8 | P7 - Verificar la versión del producto a liberar | manual | 1.83d | 2014-11-11 | 2014-11-11 |  |
| 631 | 7.1.5.9 | P8 - Pruebas beta del producto | manual | 1.83d | 2014-11-11 | 2014-11-11 |  |

| ID | WBS | Task | Type | Duration | Start | Finish | Total slack |
| --- | --- | --- | --- | --- | --- | --- | --- |
| 632 | 7.1.6 | **Implementación** |  | 1.83d | 2014-11-11 | 2014-11-11 | 0d |
| 633 | 7.1.6.1 | I6 - Documentación técnica | manual | 1.83d | 2014-11-11 | 2014-11-11 |  |
| 634 | 7.1.7 | **Verificación** |  | 1.83d | 2014-11-11 | 2014-11-11 | 0d |
| 635 | 7.1.7.1 | V10 - Realizar el informe final de verificación | manual | 1.83d | 2014-11-11 | 2014-11-11 |  |
| 636 | 7.1.7.2 | V6 - Generar entorno de prueba | manual | 1.83d | 2014-11-11 | 2014-11-11 |  |
| 637 | 7.1.7.3 | V7 - Ejecutar las prueba | manual | 1.83d | 2014-11-11 | 2014-11-11 |  |
| 638 | 7.1.7.4 | V8 - Pruebas del sistema | manual | 1.83d | 2014-11-11 | 2014-11-11 |  |
| 639 | 7.1.7.5 | V9 - Evaluar la verificación | manual | 1.83d | 2014-11-11 | 2014-11-11 |  |
| 640 | 7.1.8 | **Comunicación** |  | 1.83d? | 2014-11-11 | 2014-11-11 | 0d |
| 641 | 7.1.8.1 | CM4 - Gestión de "Lecciones Aprendidas" | manual | 1.83d? | 2014-11-11 | 2014-11-11 |  |
| 642 | 7.2 | Fin de Fase | milestone, manual | 0d | 2014-11-11 | 2014-11-11 |  |
| 643 | 7.3 | Fin de proyecto | milestone, manual | 0d | 2014-11-11 | 2014-11-11 |  |
